# Puesta en marcha e_orchestra

Schedule from MS Project, 2006-05-11 to 2006-07-10.
GWT

## Calendars

- Standard: Mon-Fri 08:00-12:00, 13:00-17:00; Sat-Sun off. Exceptions (off unless hours are given): 2006-07-05.

## Resources

| Resource |
| --- |
| Katy Martin |
| Listbeth Rojas |
| Loredana Russo |
| Giovanni Savoca |
| Aron Levy |
| QA |

## Schedule

| ID | WBS | Task | Type | Duration | Start | Finish | Predecessors | Total slack | Free slack | Constraint | Resources | Work |
| --- | --- | --- | --- | --- | --- | --- | --- | --- | --- | --- | --- | --- |
| 1 | 1 | **Puesta en marcha de e_Orchestra** |  | 42d | 2006-05-11 | 2006-07-10 |  | 0d |  |  |  | 598.67h |
| 2 | 1.1 | **Definir Herramientas,Técnicas y Plantillas** |  | 15d | 2006-05-11 | 2006-05-31 |  | 27d |  |  |  | 68.8h |
| 3 | 1.1.1 | Gerencia de Proyectos |  | 7d | 2006-05-11 | 2006-05-19 |  | 35d |  | start no earlier than 2006-05-11 | Listbeth Rojas [50%] | 28h |
| 4 | 1.1.2 | Operación, Mant y Soporte (OMS) |  | 2d | 2006-05-17 | 2006-05-18 |  | 36d |  | start no earlier than 2006-05-17 | Aron Levy [25%]; Giovanni Savoca [25%] | 8h |
| 5 | 1.1.3 | Informar a Katy (Tierra Network) para revisión |  | 1d | 2006-05-16 | 2006-05-16 |  | 38d |  | start no earlier than 2006-05-16 | Listbeth Rojas [25%] | 2h |
| 6 | 1.1.4 | Reunión revisión plantillas y acordar acciones |  | 1d | 2006-05-17 | 2006-05-17 |  | 32d | 0d | start no earlier than 2006-05-17 | Listbeth Rojas [25%]; Katy Martin [25%] | 4h |
| 7 | 1.1.5 | Revisión por parte de Tierra Network y GWT |  | 3d | 2006-05-18 | 2006-05-22 | 6 | 32d | 0d |  | Katy Martin [25%]; Giovanni Savoca [25%] | 10.8h |
| 8 | 1.1.6 | Ajustes recomendados por Tierra Network y GWT (S/A) |  | 2d | 2006-05-23 | 2006-05-24 | 7 | 32d |  |  | Listbeth Rojas [50%] | 8h |
| 9 | 1.1.7 | Elaborar plantilla esp. req. Holanda |  | 4d | 2006-05-26 | 2006-05-31 |  | 27d | 0d | start no earlier than 2006-05-26 | Katy Martin [25%] | 8h |
| 10 | 1.1.8 | Enviar plantilla a Listbeth para revisión | milestone | 0d | 2006-05-31 | 2006-05-31 | 9 | 27d | 0d |  | Katy Martin |  |
| 11 | 1.2 | Plantillas revisadas y acordadas | milestone | 0d | 2006-05-31 | 2006-05-31 | 10 | 32d |  |  |  |  |
| 12 | 1.3 | **Procesos y Metodologías** |  | 6d | 2006-05-19 | 2006-05-26 |  | 15d |  |  |  | 23.2h |
| 13 | 1.3.1 | Revisión Metodología Desarrollo de Soluciones |  | 2d | 2006-05-19 | 2006-05-22 |  | 15d | 0d | start no earlier than 2006-05-19 | Katy Martin [25%]; Giovanni Savoca [25%] | 8h |
| 14 | 1.3.2 | Revisión de la documentación de Procesos |  | 2d | 2006-05-23 | 2006-05-24 | 13 | 15d | 0d | start no earlier than 2006-05-17 | Katy Martin [25%]; Listbeth Rojas [25%] | 7.2h |
| 15 | 1.3.3 | Realizar ajustes Metodología y Procesos (S/A) |  | 2d | 2006-05-25 | 2006-05-26 | 14 | 15d | 0d |  | Listbeth Rojas [50%] | 8h |
| 16 | 1.4 | Procesos y Metodología definida | milestone | 0d | 2006-05-26 | 2006-05-26 | 15 | 20d | 0d |  |  |  |
| 17 | 1.5 | **Estrategia Comunicacional** |  | 15d | 2006-05-29 | 2006-06-16 |  | 15d |  |  |  | 70h |
| 18 | 1.5.1 | Definir esquema de comunicación a los equipos de Trab |  | 5d | 2006-05-29 | 2006-06-02 | 16 | 15d | 0d |  | Katy Martin [25%]; Listbeth Rojas [25%]; Giovanni Savoca [25%] | 30h |
| 19 | 1.5.2 | Preparar material de apoyo |  | 10d | 2006-06-05 | 2006-06-16 | 18 | 15d |  |  | Listbeth Rojas; Katy Martin [25%] | 40h |
| 20 | 1.6 | **Conformación Equipo Aseguramiento Calidad** |  | 6d | 2006-05-29 | 2006-06-05 |  | 24d |  |  |  | 40.67h |
| 21 | 1.6.1 | Sesión de Trabajo personas designadas QA |  | 1d | 2006-05-29 | 2006-05-29 | 16 | 24d | 0d |  | Listbeth Rojas [50%]; Katy Martin [50%] | 6.67h |
| 22 | 1.6.2 | Establecer lineamientos y reglas de trabajo |  | 3d | 2006-05-30 | 2006-06-01 | 21 | 24d | 0d |  | Katy Martin [25%]; Listbeth Rojas [25%]; Giovanni Savoca [25%] | 18h |
| 23 | 1.6.3 | Documentación procesos y procedimientos |  | 2d | 2006-06-02 | 2006-06-05 | 22 | 24d | 0d |  | Listbeth Rojas | 16h |
| 24 | 1.7 | Equipo de Aseguramiento de Calidad Conformado | milestone | 0d | 2006-06-05 | 2006-06-05 | 23 | 29d |  |  |  |  |

Notes:
- 4: Esta actividad incluye la definición de herramientas / plantillas para Control de Cambios, solic de preparación de ambientes de desarrollo y producción y cualquier otra actividad que involucre la solicitudes del equipo de proyectos a OMS

| ID | WBS | Task | Type | Duration | Start | Finish | Predecessors | Total slack | Free slack | Constraint | Resources | Work |
| --- | --- | --- | --- | --- | --- | --- | --- | --- | --- | --- | --- | --- |
| 25 | 1.8 | **Implantación Help Desk GWT** |  | 36d | 2006-05-17 | 2006-07-06 |  | 0d |  |  |  | 218h |
| 26 | 1.8.1 | Análisis de la solución y status HD actual |  | 4d | 2006-05-17 | 2006-05-22 |  | 0d |  | start no earlier than 2006-05-17 | Listbeth Rojas [50%]; Loredana Russo [50%] | 32h |
| 27 | 1.8.2 | Revisión del HD actual y emisión de comentarios |  | 5d | 2006-06-01 | 2006-06-07 |  | 22d |  | start no earlier than 2006-06-01 | Katy Martin [50%] | 20h |
| 28 | 1.8.3 | Configurar aplicación |  | 20d | 2006-05-23 | 2006-06-19 | 26 | 0d |  |  | Loredana Russo [50%] | 80h |
| 29 | 1.8.4 | Pruebas integrales (QA) |  | 5d | 2006-06-20 | 2006-06-26 | 28 | 0d |  |  | Listbeth Rojas [25%]; QA | 50h |
| 30 | 1.8.5 | Realizar ajustes de funcionalidad |  | 5d | 2006-06-27 | 2006-07-03 | 29 | 0d |  |  | Loredana Russo [50%] | 20h |
| 31 | 1.8.6 | Pase a Producción |  | 2d | 2006-07-04 | 2006-07-06 | 30 | 0d |  |  | Aron Levy | 16h |
| 32 | 1.8.7 | Puesta en marcha | milestone | 0d | 2006-07-06 | 2006-07-06 | 31 | 0d |  |  | Listbeth Rojas; Loredana Russo; Aron Levy |  |
| 33 | 1.9 | Help Desk implantado y funcionando | milestone | 0d | 2006-07-06 | 2006-07-06 | 32 | 0d |  |  |  |  |
| 34 | 1.10 | Manejo del cambio |  | 15d | 2006-06-15 | 2006-07-06 |  | 2d |  | start no earlier than 2006-06-15 | Katy Martin [25%]; Listbeth Rojas [25%] | 60h |
| 35 | 1.11 | **Incorporación en GEDI documentación definida** |  | 35d | 2006-05-16 | 2006-07-03 |  | 4d |  |  |  | 70h |
| 36 | 1.11.1 | Definir estructura, crear carpetas e incluir documentos |  | 35d | 2006-05-16 | 2006-07-03 |  | 4d | 0d | start no earlier than 2006-05-16 | Listbeth Rojas [25%] | 70h |
| 37 | 1.12 | Documentación estandar en GEDI | milestone | 0d | 2006-07-03 | 2006-07-03 | 36 | 4d |  |  |  |  |
| 38 | 1.13 | Traducción documentación a Inglés |  | 20d | 2006-05-31 | 2006-06-27 |  | 14d | 0d | start no earlier than 2006-05-31 |  |  |
| 39 | 1.14 | Cierre de actividades |  | 2d | 2006-07-07 | 2006-07-10 | 33 | 0d |  |  | Katy Martin; Listbeth Rojas; Giovanni Savoca | 48h |

Notes:
- 35: Actividad continua, donde se comprten documentos y se registran los resultantes
