# Proyecto CRM - Corporacion Union

Schedule from MS Project, 2005-11-29 to 2006-01-31.

## Calendars

- Estándar: Mon-Fri 08:00-12:00, 13:00-17:00; Sat-Sun off.

## Resources

| Resource |
| --- |
| Aron |
| Kathy |
| Felix |
| Yorka |
| Cliente |

## Schedule

| ID | WBS | Task | Type | Duration | Start | Finish | Predecessors | Total slack | Free slack | Resources | Work |
| --- | --- | --- | --- | --- | --- | --- | --- | --- | --- | --- | --- |
| 1 | 1 | **Borsa Jove d'Habitatge** |  | 46d | 2005-11-29 | 2006-01-31 |  | 0d |  |  | 96h |
| 2 | 1.1 | **Inicio** |  | 0.25d | 2005-11-29 | 2005-11-29 |  | 45.75d |  |  | 2h |
| 3 | 1.1.1 | Reunión de Arranque (Kickoff) |  | 2h | 2005-11-29 | 2005-11-29 |  | 45.75d |  | Kathy | 2h |
| 4 | 1.2 | **Especificación de Requerimientos** |  | 9.38d | 2005-11-29 | 2005-12-12 |  | 36.62d |  |  | 94h |
| 5 | 1.2.1 | **Levantamiento de Información** |  | 0.25d | 2005-11-29 | 2005-11-29 |  | 45.75d |  |  | 8h |
| 6 | 1.2.1.1 | Sesión de Trabajo # 1 |  | 2h | 2005-11-29 | 2005-11-29 |  | 45.75d |  | Kathy; Cliente | 4h |
| 7 | 1.2.1.2 | Sesión de Trabajo # 2 |  | 2h | 2005-11-29 | 2005-11-29 |  | 45.75d |  | Kathy; Cliente | 4h |
| 8 | 1.2.2 | Elaboración del Informe Esp. de Req. y Matriz de Req. |  | 5d | 2005-11-29 | 2005-12-05 |  | 36.62d | 0d | Kathy | 40h |
| 9 | 1.2.3 | Entrega al Equipo de Proyecto para su revisión | milestone | 0d | 2005-12-05 | 2005-12-05 | 8 | 36.62d | 0d | Kathy |  |
| 10 | 1.2.4 | Revisión por parte del Equipo de Proyecto |  | 3h | 2005-12-06 | 2005-12-06 | 9 | 36.62d | 0d | Kathy; Yorka | 6h |
| 11 | 1.2.5 | Ajustes al Informe Especificación de Requerimientos |  | 1d | 2005-12-06 | 2005-12-07 | 10 | 36.62d | 0d | Kathy; Yorka | 16h |
| 12 | 1.2.6 | Entrega de Especificación de Requerimientos para aprobación | milestone | 0d | 2005-12-07 | 2005-12-07 | 11 | 36.62d | 0d | Kathy |  |
| 13 | 1.2.7 | Revisión por parte del Cliente |  | 3d | 2005-12-07 | 2005-12-12 | 12 | 36.62d | 0d | Cliente | 24h |
| 14 | 1.2.8 | Aprobación del Informe Especificación de Requerimientos | milestone | 0d | 2005-12-12 | 2005-12-12 | 13, 12 | 36.62d | 0d | Cliente |  |
| 15 | 1.3 | Informe Especificación de Requerimientos Aprobado | milestone | 0d | 2005-12-12 | 2005-12-12 | 14 | 36.62d |  |  |  |
| 16 | 1.4 | **Configuración y Desarrollo** |  | 8d | 2005-11-29 | 2005-12-08 |  | 0d |  |  |  |
| 17 | 1.4.1 | Cofiguración de WIB y creación de páginas |  | 8h | 2005-11-29 | 2005-11-29 |  | 7d | 0d |  |  |
| 18 | 1.4.2 | Configuración y pesonalización de N2C |  | 8h | 2005-11-29 | 2005-11-29 |  | 7d |  |  |  |
| 19 | 1.4.3 | Creación de tablas básicas |  | 8h | 2005-11-29 | 2005-11-29 |  | 7d |  |  |  |
| 20 | 1.4.4 | Creación de reportes |  | 8h | 2005-11-29 | 2005-11-29 |  | 7d |  |  |  |
| 21 | 1.4.5 | **Desarrollo de Funcionalidades** |  | 8d | 2005-11-29 | 2005-12-08 |  | 0d |  |  |  |
| 22 | 1.4.5.1 | Menú |  | 12h | 2005-11-29 | 2005-11-30 |  | 6.5d |  |  |  |
| 23 | 1.4.5.2 | Site Map |  | 4h | 2005-11-29 | 2005-11-29 |  | 7.5d |  |  |  |
| 24 | 1.4.5.3 | Contact |  | 8h | 2005-11-29 | 2005-11-29 |  | 7d |  |  |  |
| 25 | 1.4.5.4 | Búsqueda básica |  | 8h | 2005-11-29 | 2005-11-29 |  | 7d |  |  |  |
| 26 | 1.4.5.5 | Galería de Imágenes |  | 16h | 2005-11-29 | 2005-11-30 |  | 6d |  |  |  |
| 27 | 1.4.5.6 | Noticias |  | 16h | 2005-11-29 | 2005-11-30 |  | 6d |  |  |  |
| 28 | 1.4.5.7 | Suscripción/Newsletter |  | 32h | 2005-11-29 | 2005-12-02 |  | 4d |  |  |  |
| 29 | 1.4.5.8 | Manejo de Multilenguaje (2 idiomas) |  | 16h | 2005-11-29 | 2005-11-30 |  | 6d |  |  |  |
| 30 | 1.4.5.9 | Administración de transacciones inmoviliarias |  | 8d | 2005-11-29 | 2005-12-08 |  | 0d |  |  |  |
| 31 | 1.4.6 | Ejecución de pruebas internas |  | 5d | 2005-11-29 | 2005-12-05 |  | 3d |  |  |  |
| 32 | 1.5 | Nuevas funcionalidades | milestone | 0d | 2005-11-29 | 2005-11-29 |  | 46d |  |  |  |

Notes:
- 1: 1) Esta plantilla pretende apoyar al Gerente de proyecto en la elaboración de cronogramas de proyectos para el desarrollo y configuración de soluciones. Especifica las actividades y los productos obtenidos en cada actividad o grupo de ellas. / 2) La planificación se está realizando por días laborables. Si en una actividad no se requiere esfuerzo de días completos (8 horas) para una actividad, entonces se especifica el porcentaje (%) de dedicación a la actividad. Por ejemplo, si se tiene una tarea con duración de 1 día, pero el recurso le va a dedicar solo4 horas, en la asignación del recurso se colocaría 50%.
- 3: Esta tarea representa la reunión con el cliente o equipo de proyecto, para la formalización del iincio del proyecto (en aquellos casos que aplique). Aquí no se contempla el tiempo que dedica el Gerente del Proyecto a la preparación de la presentación para esta reunión, debido a que las actividades en este plan se reflejan a partir de este arranque.
- 5: Se estima un día por sesión de levantamiento de requerimientos. Existen proyectos donde el lev. de información se hace con ejecución de talleres con duración estimada de 2 días hasta una semana. Todo depende. Lo importante es reflejar cada sesión, duración y las fechas pautadas para su ejecución.
- 16: Los tiempos a incorporar en las tareas que se presentan a continuación dependerán de la complejidad del proyecto a nivel de aplicaciones, configuración de herramientas del kernel, Site, etc.
- 21: En caso de que el proyecto contemple varias aplicaciones, se recomienda dimensionar cada una por separado, además de especificar precedencia en caso de que exista

| ID | WBS | Task | Type | Duration | Start | Finish | Predecessors | Total slack | Free slack |
| --- | --- | --- | --- | --- | --- | --- | --- | --- | --- |
| 33 | 1.6 | **Plan de Pruebas** |  | 5d | 2005-11-29 | 2005-12-05 |  | 41d |  |
| 34 | 1.6.1 | Elaboración Plan de Pruebas |  | 3d | 2005-11-29 | 2005-12-01 |  | 41d | 0d |
| 35 | 1.6.2 | Revisión Plan de Pruebas con Equipo de Trabajo |  | 1d | 2005-12-02 | 2005-12-02 | 34 | 41d | 0d |
| 36 | 1.6.3 | Ajustes recomendados al Plan de Pruebas |  | 1d | 2005-12-05 | 2005-12-05 | 35 | 41d | 0d |
| 37 | 1.7 | Plan de Pruebas elaborado y revisado | milestone | 0d | 2005-12-05 | 2005-12-05 | 36 | 41d |  |
| 38 | 1.8 | **Pruebas de Certificación** |  | 15d | 2005-12-09 | 2005-12-29 |  | 0d |  |
| 39 | 1.8.1 | Preparación para las pruebas en ambiente de desarrollo |  | 3d | 2005-12-09 | 2005-12-13 | 16, 32 | 0d |  |
| 40 | 1.8.2 | Realización de Pruebas de Funcionalidad |  | 7d | 2005-12-14 | 2005-12-22 | 39 | 0d |  |
| 41 | 1.8.3 | Realización de Ajustes recomendados |  | 5d | 2005-12-23 | 2005-12-29 | 40 | 0d |  |
| 42 | 1.8.4 | Pruebas de Certificación aprobada | milestone | 0d | 2005-12-29 | 2005-12-29 | 41 | 0d |  |
| 43 | 1.9 | Documentación |  | 15d | 2005-11-29 | 2005-12-19 |  | 31d |  |
| 44 | 1.10 | **Preparación para el aranque** |  | 25d | 2005-11-30 | 2006-01-03 |  | 20d |  |
| 45 | 1.10.1 | **Desarrollo** |  | 3d | 2005-11-30 | 2005-12-02 |  | 42d |  |
| 46 | 1.10.1.1 | Configuración Infraestructura Técnica |  | 3d | 2005-11-30 | 2005-12-02 | 17 | 42d |  |
| 47 | 1.10.2 | **Producción** |  | 3d | 2005-12-30 | 2006-01-03 |  | 0d |  |
| 48 | 1.10.2.1 | Configuración Infraestructura Técnica |  | 3d | 2005-12-30 | 2006-01-03 | 42 | 0d |  |
| 49 | 1.11 | **Puesta en Producción** |  | 20d | 2006-01-04 | 2006-01-31 | 47 | 0d |  |
| 50 | 1.11.1 | Adiestramiento |  | 10d | 2006-01-04 | 2006-01-17 |  | 10d |  |
| 51 | 1.11.2 | Manejo del Cambio |  | 20d | 2006-01-04 | 2006-01-31 |  | 0d |  |
| 52 | 1.11.3 | **Gerencia de Proyecto** |  | 10d | 2006-01-04 | 2006-01-17 |  | 10d |  |
| 53 | 1.11.3.1 | Planificación |  | 10d | 2006-01-04 | 2006-01-17 |  | 10d |  |
| 54 | 1.11.4 | **Cierre** |  | 2d | 2006-01-04 | 2006-01-05 |  | 18d |  |
| 55 | 1.11.4.1 | Preparación Presentación Cierre de Proyecto |  | 2d | 2006-01-04 | 2006-01-05 | 49 | 18d |  |
| 56 | 1.11.4.2 | Reunión Cierre de Proyecto |  | 1d | 2006-01-04 | 2006-01-04 | 55 | 19d |  |

Notes:
- 40: La duración de esta actividad depende de la cantidad y complejidad de las aplicaciones o funcionalidades configuradas como parte de los productos a entregar en el proyecto.
- 43: Esta actividad incluye la elaboración de la Guía de Usuarios, Guía Técnica y cualquier documento necesario o comprometido como parte de los productos a entregar en el proyecto. También su duración dependerá de la cantidad de aplicaciones y/o funcionalidades desarrolladas en el proyecto.
- 46: La estimación de la duración de esta actividad la debemos realizar con el equipo de Operaciones, asi como la fecha de inicio
- 48: La estimación de la duración de esta actividad la debemos realizar junto con el equipo de Operaciones, asi como la fecha de inicio
- 50: Contempla todas las tareas relacionadas con el adiestramiento, desde la preparación del material de apoyo para su ejecución, como las sesiones que se realicen para la inducción del usuario
- 51: Corresponde a todas las actividades que se realizarán en el proyecto en esta área. En algunas ocasiones lo hacemos nosotros (GWT), en otras es responsabilidad del cliente. Independientemente de ello, se considera importante reflejar su duración y fecha de inicio. A pesar que lo haga el cliente, siempre existirán horas de apoyo nuestro
- 52: Horas que dedica el Gerente de proyecto en la preparación, planificación
