# Plan New Light International_2005Sep29

Schedule from MS Project, 2006-07-03 to 2006-09-18.
GSM

## Calendars

- Standard: Mon-Fri 08:00-12:00, 13:00-17:00; Sat-Sun off.

## Resources

| Resource |
| --- |
| GWT Socio |
| GWT Lider Proyecto |
| TN Lider Proyecto |
| GWT Analista 1 |
| GWT Analista 2 |
| DC Lider Proyecto |
| TN Operaciones 1 |
| GWT Operaciones 1 |
| DC Diseñador 1 |
| GWT Programador 1 |
| GWT Programador 2 |

## Schedule

| ID | WBS | Task | Duration | Start | Finish | Predecessors | Total slack | Free slack | Resources | Work |
| --- | --- | --- | --- | --- | --- | --- | --- | --- | --- | --- |
| 1 | WBS_M_01.1 | **Proyecto DiChis** | 55.35d | 2006-07-03 08:00 | 2006-09-18 10:48 |  | 0d |  |  | 4739.35h |
| 2 | WBS_M_01.1.33 | Gerencia de Proyectos | 55.35h | 2006-07-03 08:00 | 2006-07-11 16:21 |  | 48.43d |  | GWT Socio; GWT Lider Proyecto; TN Lider Proyecto | 166.05h |
| 3 | WBS_M_01.1.34 | **Pruebas en ambiente de desarrollo** | 52d | 2006-07-03 08:00 | 2006-09-12 17:00 |  | 3.35d |  |  | 2088h |
| 4 | WBS_M_01.1.34.1 | Internas | 416h | 2006-07-03 08:00 | 2006-09-12 17:00 |  | 3.35d |  | GWT Lider Proyecto; GWT Analista 1; GWT Analista 2 | 1248h |
| 5 | WBS_M_01.1.34.2 | De certificación | 168h | 2006-07-03 08:00 | 2006-07-31 17:00 |  | 34.35d |  | TN Lider Proyecto; DC Lider Proyecto | 336h |
| 6 | WBS_M_01.1.34.3 | Ajustes tras pruebas | 168h | 2006-07-03 08:00 | 2006-07-31 17:00 |  | 34.35d |  | GWT Lider Proyecto; GWT Analista 1; GWT Analista 2 | 504h |
| 7 | WBS_M_01.1.38 | **Operación, Mantenimiento y Soporte** | 3.25d | 2006-07-03 08:00 | 2006-07-06 10:00 |  | 0d |  |  | 78h |
| 8 | WBS_M_01.1.38.1 | Actualización de documento de configuración de servidores | 2h | 2006-07-03 08:00 | 2006-07-03 10:00 |  | 0d |  | GWT Socio; TN Operaciones 1; GWT Operaciones 1 | 6h |
| 9 | WBS_M_01.1.38.2 | Adquisición de servicios de hosting | 8h | 2006-07-03 10:00 | 2006-07-04 10:00 | 8 | 0d |  | DC Lider Proyecto | 8h |
| 10 | WBS_M_01.1.38.3 | Adquisición e Instalación de PDFlib | 4h | 2006-07-04 10:00 | 2006-07-04 15:00 | 9 | 1d | 0d | GWT Socio; GWT Operaciones 1 | 8h |
| 11 | WBS_M_01.1.38.4 | Configuración y Prueba | 4h | 2006-07-04 15:00 | 2006-07-05 10:00 | 10 | 1d |  | GWT Operaciones 1 | 4h |
| 12 | WBS_M_01.1.38.5 | Instalación de N2C y WIB | 8h | 2006-07-04 10:00 | 2006-07-05 10:00 | 9 | 0d |  | GWT Operaciones 1 | 8h |
| 13 | WBS_M_01.1.38.6 | Instalación de librerias de manipulación de imágenes (Image Magick y GD) | 4h | 2006-07-04 10:00 | 2006-07-04 15:00 | 9 | 1.5d |  | GWT Operaciones 1 | 4h |
| 14 | WBS_M_01.1.38.7 | Investigación y Adquisición de versión JAVA de Aurigma | 8h | 2006-07-04 10:00 | 2006-07-05 10:00 | 9 | 0d |  | GWT Socio; GWT Lider Proyecto | 16h |
| 15 | WBS_M_01.1.38.8 | Configuración y Pruebas de versión JAVA de Aurigma | 8h | 2006-07-05 10:00 | 2006-07-06 10:00 | 14 | 0d |  | GWT Operaciones 1; GWT Lider Proyecto | 16h |
| 16 | WBS_M_01.1.38.9 | Limpieza del URL para eliminar ZZZ/…/… | 8h | 2006-07-05 10:00 | 2006-07-06 10:00 | 12 | 0d |  | GWT Operaciones 1 | 8h |
| 17 | WBS_M_01.1.48 | **Desarrollo** | 32.85d | 2006-07-06 10:00 | 2006-08-22 08:48 | 7 | 0d |  |  | 1845.3h |
| 18 | WBS_M_01.1.48.1 | **Migración BD PHS a Servidor de desarrollo** | 2d | 2006-07-06 10:00 | 2006-07-10 10:00 |  | 0d |  |  | 56h |
| 19 | WBS_M_01.1.48.1.1 | Reingeniería del Modelo de datos de BD incorporando ajustes para manejo de selecciones y blogs. | 8h | 2006-07-06 10:00 | 2006-07-07 10:00 |  | 0d |  | GWT Lider Proyecto; GWT Analista 1; GWT Analista 2 | 24h |
| 20 | WBS_M_01.1.48.1.2 | Planificación de la migración | 4h | 2006-07-06 10:00 | 2006-07-06 15:00 |  | 0.5d |  | GWT Lider Proyecto; GWT Analista 1 | 8h |
| 21 | WBS_M_01.1.48.1.3 | Creación de tablas N2C a imagen de PHS con los cambios. OJO: e-MM Català en TRADUCCIONES | 8h | 2006-07-07 10:00 | 2006-07-10 10:00 | 20, 19 | 0d |  | GWT Analista 2 | 8h |
| 22 | WBS_M_01.1.48.1.4 | Traducción de términos $MM. Manejo de catalán, español e inglés en principio | 8h | 2006-07-06 10:00 | 2006-07-07 10:00 |  | 1d |  | DC Lider Proyecto; TN Lider Proyecto | 16h |
| 23 | WBS_M_01.1.48.6 | **Migración aplicación PHS** | 4d | 2006-07-10 10:00 | 2006-07-14 10:00 | 18 | 0d |  |  | 112h |
| 24 | WBS_M_01.1.48.6.1 | Construcción de mapa de navegación de PHS | 8h | 2006-07-10 10:00 | 2006-07-11 10:00 |  | 0d |  | GWT Lider Proyecto; GWT Analista 1; GWT Analista 2 | 24h |
| 25 | WBS_M_01.1.48.6.2 | Casos de Uso PHS | 8h | 2006-07-11 10:00 | 2006-07-12 10:00 | 24 | 0d |  | GWT Lider Proyecto; GWT Analista 1; GWT Analista 2 | 24h |
| 26 | WBS_M_01.1.48.6.3 | Adaptación de Casos de Uso PHS incorporando DiChis | 16h | 2006-07-12 10:00 | 2006-07-14 10:00 | 25 | 0d |  | GWT Lider Proyecto; GWT Analista 1; GWT Analista 2 | 48h |
| 27 | WBS_M_01.1.48.6.4 | Pantalla de unificación de funcionalidades de back office -al estilo WIB- Start page | 8h | 2006-07-10 10:00 | 2006-07-11 10:00 |  | 3d |  | GWT Analista 1 | 8h |
| 28 | WBS_M_01.1.48.6.5 | Verificación de funcionalidades de B.O. que se pueden probar hasta este punto. | 8h | 2006-07-10 10:00 | 2006-07-11 10:00 |  | 3d |  | GWT Analista 2 | 8h |

| ID | WBS | Task | Duration | Start | Finish | Predecessors | Total slack | Free slack | Resources | Work |
| --- | --- | --- | --- | --- | --- | --- | --- | --- | --- | --- |
| 29 | WBS_M_01.1.48.12 | **Revisión y ajuste de programas recurrentes** | 2.5d | 2006-07-14 10:00 | 2006-07-18 15:00 | 23 | 24.35d |  |  | 20h |
| 30 | WBS_M_01.1.48.12.1 | arriba | 5h | 2006-07-14 10:00 | 2006-07-14 16:00 |  | 24.35d | 0d | GWT Lider Proyecto | 5h |
| 31 | WBS_M_01.1.48.12.2 | cabecera | 10h | 2006-07-14 16:00 | 2006-07-18 09:00 | 30 | 24.35d | 0d | GWT Lider Proyecto | 10h |
| 32 | WBS_M_01.1.48.12.3 | pie | 5h | 2006-07-18 09:00 | 2006-07-18 15:00 | 31 | 24.35d |  | GWT Lider Proyecto | 5h |
| 33 | WBS_M_01.1.48.16 | Definición de L&F Lineamientos a seguir en el site (reglas generales) | 8h | 2006-07-06 10:00 | 2006-07-07 10:00 |  | 31.85d |  | DC Diseñador 1 | 8h |
| 34 | WBS_M_01.1.48.17 | **Ajuste de páginas de contenido** | 5.25d | 2006-07-14 10:00 | 2006-07-21 12:00 | 23 | 21.6d |  |  | 66h |
| 35 | WBS_M_01.1.48.17.1 | Definición de L&F | 8h | 2006-07-14 10:00 | 2006-07-17 10:00 |  | 21.6d | 0d | DC Diseñador 1 | 8h |
| 36 | WBS_M_01.1.48.17.2 | Ajuste de L&F | 10h | 2006-07-17 10:00 | 2006-07-18 12:00 | 35 | 21.6d | 0d | GWT Programador 1 | 10h |
| 37 | WBS_M_01.1.48.17.3 | Actualización del contenido (ver anexo). Considerar mecanismo para multiidioma | 24h | 2006-07-18 13:00 | 2006-07-21 12:00 | 36 | 21.6d |  | TN Lider Proyecto; DC Lider Proyecto | 48h |
| 38 | WBS_M_01.1.48.21 | **Ajuste de páginas con párrafos de aplicación** | 3.25d | 2006-07-14 10:00 | 2006-07-19 12:00 | 23 | 23.6d |  |  | 34h |
| 39 | WBS_M_01.1.48.21.1 | Definición de L&F | 8h | 2006-07-14 10:00 | 2006-07-17 10:00 |  | 23.6d | 0d | DC Diseñador 1 | 8h |
| 40 | WBS_M_01.1.48.21.2 | Ajuste de L&F | 10h | 2006-07-17 10:00 | 2006-07-18 12:00 | 39 | 23.6d | 0d | GWT Programador 2 | 10h |
| 41 | WBS_M_01.1.48.21.3 | Revisión FAQ, Boletin | 8h | 2006-07-18 13:00 | 2006-07-19 12:00 | 40 | 23.6d |  | GWT Analista 1 | 8h |
| 42 | WBS_M_01.1.48.21.4 | Revisión de registro de usuarios | 8h | 2006-07-18 13:00 | 2006-07-19 12:00 | 40 | 23.6d |  | GWT Analista 2 | 8h |
| 43 | WBS_M_01.1.48.26 | **Módulo de Admin de Cliente (MAC)** | 4d | 2006-07-14 10:00 | 2006-07-20 10:00 | 23 | 22.85d |  |  | 32h |
| 44 | WBS_M_01.1.48.26.1 | Definición de L&F | 8h | 2006-07-14 10:00 | 2006-07-17 10:00 |  | 22.85d | 0d | DC Diseñador 1 | 8h |
| 45 | WBS_M_01.1.48.26.2 | Ajuste de L&F | 24h | 2006-07-17 10:00 | 2006-07-20 10:00 | 44 | 22.85d |  | GWT Lider Proyecto | 24h |
| 46 | WBS_M_01.1.48.29 | **Upload de fotos** | 2.75d | 2006-07-14 10:00 | 2006-07-18 17:00 | 23 | 0d |  |  | 38h |
| 47 | WBS_M_01.1.48.29.1 | Definición de L&F | 8h | 2006-07-14 10:00 | 2006-07-17 10:00 |  | 0.75d |  | DC Diseñador 1 | 8h |
| 48 | WBS_M_01.1.48.29.2 | Incorporación de Upload Aurigma en versión java. Considerar tiempo de investigación. | 6h | 2006-07-14 10:00 | 2006-07-14 17:00 |  | 0d |  | GWT Lider Proyecto; GWT Analista 2 | 12h |
| 49 | WBS_M_01.1.48.29.3 | Desactivar botón de envío por espacio insuficiente. | 2h | 2006-07-17 08:00 | 2006-07-17 10:00 | 48 | 1.75d |  | GWT Lider Proyecto | 2h |
| 50 | WBS_M_01.1.48.29.4 | Extraer metadata de las fotos al momento de la subida y asociarla al registro de la foto en BD (requiere investigación) | 8h | 2006-07-17 08:00 | 2006-07-17 17:00 | 48 | 0d |  | GWT Analista 1 | 8h |
| 51 | WBS_M_01.1.48.29.5 | Ajuste de L&F (versión java y tradicional) | 8h | 2006-07-18 08:00 | 2006-07-18 17:00 | 47, 50 | 0d |  | GWT Programador 1 | 8h |
| 52 | WBS_M_01.1.48.35 | **Administración de Carpetas** | 3d | 2006-07-19 08:00 | 2006-07-21 17:00 | 46 | 3.6d | 0d |  | 60h |
| 53 | WBS_M_01.1.48.35.1 | Definición de L&F | 8h | 2006-07-19 08:00 | 2006-07-19 17:00 |  | 3.6d | 0d | DC Diseñador 1 | 8h |
| 54 | WBS_M_01.1.48.35.2 | Revisión de opciones de administración de carpetas: renombrar carpeta, cambiar portada, copiar carpeta, eliminar carpeta | 8h | 2006-07-19 08:00 | 2006-07-19 17:00 |  | 4.6d | 0d | GWT Lider Proyecto | 8h |
| 55 | WBS_M_01.1.48.35.3 | Verificación de nombre de carpeta física versus nombre interno para evitar aborto de mkdir | 8h | 2006-07-20 08:00 | 2006-07-20 17:00 | 54 | 4.6d |  | GWT Analista 2 | 8h |
| 56 | WBS_M_01.1.48.35.4 | Eliminación de opción de compartir a nivel de carpeta | 4h | 2006-07-19 08:00 | 2006-07-19 12:00 |  | 6.1d |  | GWT Analista 1 | 4h |
| 57 | WBS_M_01.1.48.35.5 | Ajuste de L&F | 16h | 2006-07-20 08:00 | 2006-07-21 17:00 | 53 | 3.6d |  | GWT Lider Proyecto; GWT Programador 2 | 32h |

| ID | WBS | Task | Duration | Start | Finish | Predecessors | Total slack | Free slack | Resources | Work |
| --- | --- | --- | --- | --- | --- | --- | --- | --- | --- | --- |
| 58 | WBS_M_01.1.48.41 | **Administración de imágenes en carpetas** | 3d | 2006-07-19 08:00 | 2006-07-21 17:00 | 46 | 0d |  |  | 77.6h |
| 59 | WBS_M_01.1.48.41.1 | Definición de L&F | 8h | 2006-07-19 08:00 | 2006-07-19 17:00 |  | 21.5d | 0d | DC Diseñador 1 | 8h |
| 60 | WBS_M_01.1.48.41.2 | Visualización de fotos: tamaño de visualización más grande, mostrar descripción de la foto. | 16h | 2006-07-19 08:00 | 2006-07-20 17:00 |  | 0d |  | GWT Analista 2 | 16h |
| 61 | WBS_M_01.1.48.41.3 | Revisión de opciones de administración de imágenes: renombrar imagen, copiar imagen, mover imagen, eliminar imagen, editar imagen. | 8h | 2006-07-21 08:00 | 2006-07-21 17:00 | 60 | 21.1d |  | GWT Lider Proyecto | 8h |
| 62 | WBS_M_01.1.48.41.4 | **Detalle de foto** | 1d | 2006-07-21 08:00 | 2006-07-21 17:00 | 60 | 21.1d |  |  | 20h |
| 63 | WBS_M_01.1.48.41.4.1 | Edición de datos de foto | 8h | 2006-07-21 08:00 | 2006-07-21 17:00 |  | 21.1d |  | GWT Analista 1 | 8h |
| 64 | WBS_M_01.1.48.41.4.2 | Descarga de foto original | 2h | 2006-07-21 08:00 | 2006-07-21 10:00 |  | 21.85d |  | GWT Analista 1 | 2h |
| 65 | WBS_M_01.1.48.41.4.3 | Click sobre foto lleva a edición avanzada | 2h | 2006-07-21 08:00 | 2006-07-21 10:00 |  | 21.85d |  | GWT Analista 1 | 2h |
| 66 | WBS_M_01.1.48.41.4.4 | Incluir metadata en datos de foto desplegada | 8h | 2006-07-21 08:00 | 2006-07-21 17:00 |  | 21.1d |  | GWT Analista 1 | 8h |
| 67 | WBS_M_01.1.48.41.9 | Ajuste de L&F | 12.8h | 2006-07-20 08:00 | 2006-07-21 13:48 | 59 | 21.5d |  | GWT Programador 1; GWT Analista 1 | 25.6h |
| 68 | WBS_M_01.1.48.51 | **Edición de imágenes** | 3.8d | 2006-07-21 08:00 | 2006-07-26 15:24 | 60 | 0d |  |  | 38.4h |
| 69 | WBS_M_01.1.48.51.1 | Definición de L&F | 6.4h | 2006-07-21 08:00 | 2006-07-21 15:24 |  | 0d |  | DC Diseñador 1 | 6.4h |
| 70 | WBS_M_01.1.48.51.2 | Revisión de edición avanzada de fotos: Ojos rojos, Rotación, Efectos -blanco y negro / sepia- | 8h | 2006-07-21 08:00 | 2006-07-21 17:00 |  | 2.8d |  | GWT Lider Proyecto | 8h |
| 71 | WBS_M_01.1.48.51.3 | Ajuste de L&F | 24h | 2006-07-21 15:24 | 2006-07-26 15:24 | 69 | 0d |  | GWT Analista 2 | 24h |
| 72 | WBS_M_01.1.48.55 | **Administración de cuenta del cliente** | 4d | 2006-07-14 10:00 | 2006-07-20 10:00 | 23 | 22.85d |  |  | 32h |
| 73 | WBS_M_01.1.48.55.1 | Definición de L&F | 8h | 2006-07-14 10:00 | 2006-07-17 10:00 |  | 22.85d | 0d | DC Diseñador 1 | 8h |
| 74 | WBS_M_01.1.48.55.2 | Ajuste de L&F | 16h | 2006-07-17 10:00 | 2006-07-19 10:00 | 73 | 22.85d | 0d | GWT Analista 2 | 16h |
| 75 | WBS_M_01.1.48.55.3 | Revisión de administración de cuenta del cliente | 8h | 2006-07-19 10:00 | 2006-07-20 10:00 | 74 | 22.85d |  | GWT Lider Proyecto | 8h |
| 76 | WBS_M_01.1.48.59 | **Libreta de contactos** | 4d | 2006-07-14 10:00 | 2006-07-20 10:00 | 23 | 22.85d |  |  | 108h |
| 77 | WBS_M_01.1.48.59.1 | Definición de L&F | 8h | 2006-07-14 10:00 | 2006-07-17 10:00 |  | 22.85d | 0d | DC Diseñador 1 | 8h |
| 78 | WBS_M_01.1.48.59.2 | Ajustes de L&F | 24h | 2006-07-17 10:00 | 2006-07-20 10:00 | 77 | 22.85d |  | GWT Lider Proyecto; GWT Analista 2 | 48h |
| 79 | WBS_M_01.1.48.59.3 | Detectar que un agregado a la libreta de contactos está registrado y permitir incluirlo en un grupo | 4h | 2006-07-14 10:00 | 2006-07-14 15:00 |  | 26.35d |  | GWT Analista 2 | 4h |
| 80 | WBS_M_01.1.48.59.4 | Invitar a dichis.com | 8h | 2006-07-14 10:00 | 2006-07-17 10:00 |  | 25.85d |  | GWT Lider Proyecto; GWT Programador 1 | 16h |
| 81 | WBS_M_01.1.48.59.5 | Visualización, edición, creación y eliminación de un grupo (Detalle grupo) | 9.6h | 2006-07-14 10:00 | 2006-07-17 11:36 |  | 24.85d | 0d | GWT Analista 1; GWT Analista 2 | 19.2h |
| 82 | WBS_M_01.1.48.59.6 | Visualización, edición, creación y eliminación de Mis grupos | 6.4h | 2006-07-17 11:36 | 2006-07-18 10:00 | 81 | 24.85d |  | GWT Analista 1; GWT Analista 2 | 12.8h |

| ID | WBS | Task | Duration | Start | Finish | Predecessors | Total slack | Free slack | Resources | Work |
| --- | --- | --- | --- | --- | --- | --- | --- | --- | --- | --- |
| 83 | WBS_M_01.1.48.66 | **Proyectos** | 11.3d | 2006-07-26 15:24 | 2006-08-11 08:48 | 68 | 0d |  |  | 347.2h |
| 84 | WBS_M_01.1.48.66.1 | **Albumes** | 11.3d | 2006-07-26 15:24 | 2006-08-11 08:48 |  | 0d |  |  | 107.2h |
| 85 | WBS_M_01.1.48.66.1.7 | Reconsiderar L&F en Albumes | 36h | 2006-07-26 15:24 | 2006-08-02 10:24 |  | 0d |  | GWT Lider Proyecto | 36h |
| 86 | WBS_M_01.1.48.66.1.8 | Revisión de funcionalidad de Albumes | 24h | 2006-08-02 10:24 | 2006-08-07 10:24 | 85 | 0d |  | GWT Lider Proyecto | 24h |
| 87 | WBS_M_01.1.48.66.1.9 | Revisión de proceso de construcción del album. Considerar que una foto al ser seleccionada no debe desincorporarse del carrusel sino que debe ser marcada, de modo tal que pueda utilizarse en múltiples ocasiones | 24h | 2006-08-07 10:24 | 2006-08-10 10:24 | 86 | 0d |  | GWT Lider Proyecto | 24h |
| 88 | WBS_M_01.1.48.66.1.10 | Pruebas de imprenta | 6.4h | 2006-08-10 10:24 | 2006-08-11 08:48 | 87 | 0d |  | GWT Lider Proyecto; DC Lider Proyecto; TN Lider Proyecto | 19.2h |
| 89 | WBS_M_01.1.48.66.1.11 | Consideraciones de estampillado de productos | 2h | 2006-08-10 10:24 | 2006-08-10 13:24 | 87 | 0.55d |  | GWT Lider Proyecto | 2h |
| 90 | WBS_M_01.1.48.66.1.12 | Información adicional a ser incluida en el PDF o txt. Ejemplo: carta al usuario, etiqueta para el sobre ,etc. | 2h | 2006-08-10 10:24 | 2006-08-10 13:24 | 87 | 0.55d |  | GWT Lider Proyecto | 2h |
| 91 | WBS_M_01.1.48.66.2 | **Postales** | 3.8d | 2006-07-26 15:24 | 2006-08-01 13:48 |  | 7.5d |  |  | 47.2h |
| 92 | WBS_M_01.1.48.66.2.1 | Reconsiderar L&F en Postales | 16h | 2006-07-26 15:24 | 2006-07-28 15:24 |  | 7.5d | 0d | GWT Analista 1 | 16h |
| 93 | WBS_M_01.1.48.66.2.2 | Revisión de funcionalidad de Postales | 8h | 2006-07-28 15:24 | 2006-07-31 15:24 | 92 | 7.5d | 0d | GWT Analista 1 | 8h |
| 94 | WBS_M_01.1.48.66.2.3 | Pruebas de imprenta | 6.4h | 2006-07-31 15:24 | 2006-08-01 13:48 | 93 | 7.5d |  | GWT Lider Proyecto; DC Lider Proyecto; TN Lider Proyecto | 19.2h |
| 95 | WBS_M_01.1.48.66.2.4 | Consideraciones de estampillado de productos | 2h | 2006-07-31 15:24 | 2006-08-01 08:24 | 93 | 8.05d |  | GWT Analista 1 | 2h |
| 96 | WBS_M_01.1.48.66.2.5 | Información adicional a ser incluida en el PDF o txt. Ejemplo: carta al usuario, etiqueta para el sobre ,etc. | 2h | 2006-07-31 15:24 | 2006-08-01 08:24 | 93 | 8.05d |  | GWT Analista 1 | 2h |
| 97 | WBS_M_01.1.48.66.8 | **Regalos** | 3.8d | 2006-07-26 15:24 | 2006-08-01 13:48 |  | 7.5d |  |  | 47.2h |
| 98 | WBS_M_01.1.48.66.8.1 | Reconsiderar L&F en Regalos | 16h | 2006-07-26 15:24 | 2006-07-28 15:24 |  | 7.5d | 0d | GWT Analista 2 | 16h |
| 99 | WBS_M_01.1.48.66.8.2 | Revisión de funcionalidad de Regalos | 8h | 2006-07-28 15:24 | 2006-07-31 15:24 | 98 | 7.5d | 0d | GWT Analista 2 | 8h |
| 100 | WBS_M_01.1.48.66.8.3 | Pruebas de imprenta | 6.4h | 2006-07-31 15:24 | 2006-08-01 13:48 | 99 | 7.5d |  | GWT Analista 2; DC Lider Proyecto; TN Lider Proyecto | 19.2h |
| 101 | WBS_M_01.1.48.66.8.4 | Consideraciones de estampillado de productos | 2h | 2006-07-31 15:24 | 2006-08-01 08:24 | 99 | 8.05d |  | GWT Analista 2 | 2h |
| 102 | WBS_M_01.1.48.66.8.5 | Información adicional a ser incluida en el PDF o txt. Ejemplo: carta al usuario, etiqueta para el sobre ,etc. | 2h | 2006-07-31 15:24 | 2006-08-01 08:24 | 99 | 8.05d |  | GWT Analista 2 | 2h |
| 103 | WBS_M_01.1.48.66.14 | **Gigantografías** | 8.85d | 2006-07-26 15:24 | 2006-08-08 14:12 |  | 2.45d |  |  | 145.6h |
| 104 | WBS_M_01.1.48.66.14.1 | Definición L&F | 8h | 2006-07-26 15:24 | 2006-07-27 15:24 |  | 2.45d | 0d | DC Diseñador 1 | 8h |
| 105 | WBS_M_01.1.48.66.14.2 | **Construcción de programa de pasos para elaboración de las gigantografías** | 6.6d | 2006-07-27 15:24 | 2006-08-07 11:12 | 104 | 2.45d | 0d |  | 105.6h |
| 106 | WBS_M_01.1.48.66.14.2.1 | Pantalla de selección de material, medida y acabado | 12.8h | 2006-07-27 15:24 | 2006-07-31 11:12 |  | 2.45d | 0d | GWT Lider Proyecto; GWT Analista 1 | 25.6h |
| 107 | WBS_M_01.1.48.66.14.2.2 | Pantalla de construcción de gigantografías a partir de templates | 40h | 2006-07-31 11:12 | 2006-08-07 11:12 | 106 | 2.45d |  | GWT Lider Proyecto; GWT Analista 1 | 80h |

| ID | WBS | Task | Duration | Start | Finish | Predecessors | Total slack | Free slack | Resources | Work |
| --- | --- | --- | --- | --- | --- | --- | --- | --- | --- | --- |
| 108 | WBS_M_01.1.48.66.14.5 | **Construcción de PDF. Conexión con servidor de Mulá** | 0.25d | 2006-08-07 11:12 | 2006-08-07 14:12 | 105 | 2.45d | 0d |  | 8h |
| 109 | WBS_M_01.1.48.66.14.5.1 | Consideraciones de estampillado de productos | 2h | 2006-08-07 11:12 | 2006-08-07 14:12 |  | 2.45d |  | GWT Lider Proyecto; GWT Analista 2 | 4h |
| 110 | WBS_M_01.1.48.66.14.5.2 | Información adicional a ser incluida en el PDF o txt. Ejemplo: carta al usuario, etiqueta para el sobre ,etc. | 2h | 2006-08-07 11:12 | 2006-08-07 14:12 |  | 2.45d |  | GWT Lider Proyecto; GWT Analista 2 | 4h |
| 111 | WBS_M_01.1.48.66.14.8 | Pruebas de imprenta | 8h | 2006-08-07 14:12 | 2006-08-08 14:12 | 108 | 2.45d |  | GWT Lider Proyecto; DC Lider Proyecto; TN Lider Proyecto | 24h |
| 112 | WBS_M_01.1.48.95 | **Fotos sueltas (Quick shop)** | 3d | 2006-07-21 08:00 | 2006-07-25 17:00 | 60 | 12.1d |  |  | 56h |
| 113 | WBS_M_01.1.48.95.1 | Consideración de acabado mate y brillante | 8h | 2006-07-21 08:00 | 2006-07-21 17:00 |  | 12.1d | 0d | GWT Analista 1; GWT Analista 2 | 16h |
| 114 | WBS_M_01.1.48.95.2 | Definición de L&F | 8h | 2006-07-21 08:00 | 2006-07-21 17:00 |  | 12.1d | 0d | DC Diseñador 1 | 8h |
| 115 | WBS_M_01.1.48.95.3 | Ajuste de L&F | 16h | 2006-07-24 08:00 | 2006-07-25 17:00 | 114, 113 | 12.1d |  | GWT Analista 1; GWT Analista 2 | 32h |
| 116 | WBS_M_01.1.48.99 | **Colecciones de Partners** | 3d | 2006-08-11 08:48 | 2006-08-16 08:48 | 83 | 3.5d |  |  | 40h |
| 117 | WBS_M_01.1.48.99.1 | Definición de L&F | 8h | 2006-08-11 08:48 | 2006-08-14 08:48 |  | 3.5d | 0d | DC Diseñador 1 | 8h |
| 118 | WBS_M_01.1.48.99.2 | **Galería de Foto Mulà (sin descarga de originales)** | 2d | 2006-08-14 08:48 | 2006-08-16 08:48 | 117 | 3.5d | 0d |  | 32h |
| 119 | WBS_M_01.1.48.99.2.3 | Visualización de Galería de Foto Mulà | 8h | 2006-08-14 08:48 | 2006-08-15 08:48 |  | 3.5d | 0d | GWT Lider Proyecto; GWT Analista 1 | 16h |
| 120 | WBS_M_01.1.48.99.2.4 | Ajuste de programas para la selección de fotos para utilizar en productos | 8h | 2006-08-15 08:48 | 2006-08-16 08:48 | 119 | 3.5d |  | GWT Lider Proyecto; GWT Analista 2 | 16h |
| 121 | WBS_M_01.1.48.170 | Ajuste de L&F | 4h | 2006-08-16 08:48 | 2006-08-16 13:48 | 118 | 3.5d |  | GWT Analista 2 | 4h |
| 122 | WBS_M_01.1.48.105 | **Carrito de compras** | 5d | 2006-08-11 08:48 | 2006-08-18 08:48 | 83, 112 | 0d |  |  | 170h |
| 123 | WBS_M_01.1.48.105.1 | Definición de L&F | 8h | 2006-08-11 08:48 | 2006-08-14 08:48 |  | 0d |  | DC Diseñador 1 | 8h |
| 124 | WBS_M_01.1.48.105.2 | Ajuste de L&F | 32h | 2006-08-14 08:48 | 2006-08-18 08:48 | 123 | 0d |  | GWT Lider Proyecto; GWT Analista 2 | 64h |
| 125 | WBS_M_01.1.48.105.3 | Precio de envío (consideraciones de aliados) | 8h | 2006-08-11 08:48 | 2006-08-14 08:48 |  | 4d |  | GWT Lider Proyecto | 8h |
| 126 | WBS_M_01.1.48.105.4 | Excentar de IVA a países de Latinoamerica | 8h | 2006-08-11 08:48 | 2006-08-14 08:48 |  | 4d |  | GWT Lider Proyecto | 8h |
| 127 | WBS_M_01.1.48.105.5 | Automatizar precio de Cuentas de Oro | 10h | 2006-08-11 08:48 | 2006-08-14 10:48 |  | 3.75d |  | GWT Lider Proyecto | 10h |
| 128 | WBS_M_01.1.48.105.6 | Precio de fotografías de Galería FotoMulà para distintos productos | 16h | 2006-08-11 08:48 | 2006-08-15 08:48 |  | 3d |  | GWT Lider Proyecto; GWT Analista 2 | 32h |
| 129 | WBS_M_01.1.48.105.7 | **Manejar métodos de pago** | 3d | 2006-08-11 08:48 | 2006-08-16 08:48 |  | 2d |  |  | 40h |
| 130 | WBS_M_01.1.48.105.7.4 | Paypal (requiere investigación) | 24h | 2006-08-11 08:48 | 2006-08-16 08:48 |  | 2d |  | GWT Analista 2 | 24h |
| 131 | WBS_M_01.1.48.105.7.5 | Transferencia bancaria | 12h | 2006-08-11 08:48 | 2006-08-14 13:48 |  | 3.5d |  | GWT Analista 2 | 12h |
| 132 | WBS_M_01.1.48.105.7.6 | Tarjeta de crédito | 4h | 2006-08-11 08:48 | 2006-08-11 13:48 |  | 4.5d |  | GWT Analista 2 | 4h |
| 133 | WBS_M_01.1.48.116 | Manejo de precios en dólares y euros | 16h | 2006-07-06 10:00 | 2006-07-10 10:00 |  | 30.85d |  | GWT Analista 2 | 16h |

| ID | WBS | Task | Duration | Start | Finish | Predecessors | Total slack | Free slack | Resources | Work |
| --- | --- | --- | --- | --- | --- | --- | --- | --- | --- | --- |
| 134 | WBS_M_01.1.48.117 | **Reporte de Compras** | 2d | 2006-08-18 08:48 | 2006-08-22 08:48 | 122 | 0d |  |  | 16h |
| 135 | WBS_M_01.1.48.117.1 | Definición de L&F | 8h | 2006-08-18 08:48 | 2006-08-21 08:48 |  | 0d |  | DC Diseñador 1 | 8h |
| 136 | WBS_M_01.1.48.117.2 | Ajuste de L&F | 8h | 2006-08-21 08:48 | 2006-08-22 08:48 | 135 | 0d |  | GWT Analista 1 | 8h |
| 137 | WBS_M_01.1.48.120 | **Selecciones** | 11.5d | 2006-07-24 08:00 | 2006-08-08 12:00 | 52 | 3.6d | 0d |  | 278.1h |
| 138 | WBS_M_01.1.48.120.1 | Definición de L&F | 8h | 2006-07-24 08:00 | 2006-07-24 17:00 |  | 3.6d | 0d | DC Diseñador 1 | 8h |
| 139 | WBS_M_01.1.48.120.2 | Visualización de selecciones | 8h | 2006-07-25 08:00 | 2006-07-25 17:00 | 138 | 3.6d | 0d | GWT Analista 1 | 8h |
| 140 | WBS_M_01.1.48.120.3 | **Creación / edición de una selección** | 3d | 2006-07-26 08:00 | 2006-07-28 17:00 | 139 | 3.6d | 0d |  | 89.6h |
| 141 | WBS_M_01.1.48.120.3.1 | Escogencia y ordenamiento de fotos | 9.6h | 2006-07-26 08:00 | 2006-07-27 09:36 |  | 5.4d |  | GWT Analista 2; GWT Analista 1 | 19.2h |
| 142 | WBS_M_01.1.48.120.3.2 | Escogencia de portada y agregar descripción de la selección | 3.2h | 2006-07-26 08:00 | 2006-07-26 11:12 |  | 6.2d |  | GWT Analista 1; GWT Analista 2 | 6.4h |
| 143 | WBS_M_01.1.48.120.3.3 | Permitir la creación de la selección desde la vista de la foto -fotos en conjunto o detalle-, desde la carpeta, desde el home o desde upload. Considerar portada, descripción y ordenamiento. | 24h | 2006-07-26 08:00 | 2006-07-28 17:00 |  | 3.6d |  | GWT Analista 2; GWT Analista 1 | 48h |
| 144 | WBS_M_01.1.48.120.3.4 | Eliminación de la foto de la selección | 8h | 2006-07-26 08:00 | 2006-07-26 17:00 |  | 5.6d |  | GWT Analista 2; GWT Analista 1 | 16h |
| 145 | WBS_M_01.1.48.120.8 | **Visualización del detalle de una foto y edición de imágenes en una selección** | 3.5d | 2006-07-31 08:00 | 2006-08-03 12:00 | 140 | 3.6d | 0d |  | 76.5h |
| 146 | WBS_M_01.1.48.120.8.1 | Incorporación del carrusel de fotos | 12h | 2006-07-31 08:00 | 2006-08-01 12:00 |  | 3.6d | 0d | GWT Analista 1 | 12h |
| 147 | WBS_M_01.1.48.120.8.2 | Rotar | 16h | 2006-08-01 13:00 | 2006-08-03 12:00 | 146 | 3.6d |  | GWT Analista 1 | 16h |
| 148 | WBS_M_01.1.48.120.8.3 | Cambio de permisos: privada, pública, mis amigos, mis grupos | 8h | 2006-08-01 13:00 | 2006-08-02 12:00 | 146 | 4.6d |  | GWT Analista 1 | 8h |
| 149 | WBS_M_01.1.48.120.8.4 | Modificación del nombre, tags, Tooltip de la foto | 16h | 2006-08-01 13:00 | 2006-08-03 12:00 | 146 | 3.6d |  | GWT Analista 1 | 16h |
| 150 | WBS_M_01.1.48.120.8.5 | Descripción de la foto vinculada a la selección | 10h | 2006-08-01 13:00 | 2006-08-02 15:00 | 146 | 4.35d |  | GWT Analista 1 | 10h |
| 151 | WBS_M_01.1.48.120.8.6 | **Comentarios** | 1.81d | 2006-07-31 08:00 | 2006-08-01 15:30 |  | 5.29d |  |  | 14.5h |
| 152 | WBS_M_01.1.48.120.8.6.4 | Admisión de comentarios | 4h | 2006-07-31 08:00 | 2006-07-31 12:00 |  | 5.29d | 0d | GWT Analista 1 | 4h |
| 153 | WBS_M_01.1.48.120.8.6.5 | Opción para agregar comentarios | 8h | 2006-07-31 13:00 | 2006-08-01 12:00 | 152 | 5.29d | 0d | GWT Analista 1 | 8h |
| 154 | WBS_M_01.1.48.120.8.6.6 | Despliegue de comentarios | 2.5h | 2006-08-01 13:00 | 2006-08-01 15:30 | 153 | 5.29d |  | GWT Analista 1 | 2.5h |
| 155 | WBS_M_01.1.48.120.18 | **Visualización de grupo de Fotos** | 3d | 2006-08-03 13:00 | 2006-08-08 12:00 | 145 | 3.6d |  |  | 80h |
| 156 | WBS_M_01.1.48.120.18.1 | Tipo estándar: despliegue por páginas de 20 fotos cada una. | 24h | 2006-08-03 13:00 | 2006-08-08 12:00 |  | 3.6d |  | GWT Analista 1 | 24h |
| 157 | WBS_M_01.1.48.120.18.2 | Tipo Blog (ver en una sola pantalla todas las fotos con sus comentarios -cuando la foto es comentable-) | 8h | 2006-08-03 13:00 | 2006-08-04 12:00 |  | 5.6d |  | GWT Analista 2 | 8h |
| 158 | WBS_M_01.1.48.120.18.3 | Slideshow (investigación paquete existente) | 24h | 2006-08-03 13:00 | 2006-08-08 12:00 |  | 3.6d |  | GWT Analista 1; GWT Analista 2 | 48h |

| ID | WBS | Task | Duration | Start | Finish | Predecessors | Total slack | Free slack | Resources | Work |
| --- | --- | --- | --- | --- | --- | --- | --- | --- | --- | --- |
| 159 | WBS_M_01.1.48.120.22 | **Vigencias** | 1d | 2006-07-31 08:00 | 2006-07-31 17:00 | 140 | 9.1d |  |  | 16h |
| 160 | WBS_M_01.1.48.120.22.1 | Vigencia de la visualización de una foto en una selección | 8h | 2006-07-31 08:00 | 2006-07-31 17:00 |  | 9.1d |  | GWT Analista 1 | 8h |
| 161 | WBS_M_01.1.48.120.22.2 | Vigencia de la visualización de la selección | 8h | 2006-07-31 08:00 | 2006-07-31 17:00 |  | 9.1d |  | GWT Analista 2 | 8h |
| 162 | WBS_M_01.1.48.145 | **FotoBlog** | 3.5d | 2006-08-08 13:00 | 2006-08-11 17:00 | 137 | 6.1d |  |  | 80h |
| 163 | WBS_M_01.1.48.145.1 | Definición de L&F | 8h | 2006-08-08 13:00 | 2006-08-09 12:00 |  | 6.1d | 0d | DC Diseñador 1 | 8h |
| 164 | WBS_M_01.1.48.145.2 | **Mecanismo de censura de fotos** | 2d | 2006-08-09 13:00 | 2006-08-11 12:00 | 163 | 6.6d |  |  | 32h |
| 165 | WBS_M_01.1.48.145.2.1 | Facilidad para permitir a un cliente marcar/desmarcar una foto como ofensiva | 8h | 2006-08-09 13:00 | 2006-08-10 12:00 |  | 6.6d | 0d | GWT Lider Proyecto; GWT Analista 2 | 16h |
| 166 | WBS_M_01.1.48.145.2.2 | Reconocimiento de foto como ofensiva para el cliente | 8h | 2006-08-10 13:00 | 2006-08-11 12:00 | 165 | 6.6d |  | GWT Lider Proyecto; GWT Analista 2 | 16h |
| 167 | WBS_M_01.1.48.145.5 | Slideshow (link) | 4h | 2006-08-09 13:00 | 2006-08-09 17:00 | 163 | 8.1d |  | GWT Lider Proyecto | 4h |
| 168 | WBS_M_01.1.48.145.6 | Acceso a través de URL al estilo www.dichis.com/login_cliente | 16h | 2006-08-09 13:00 | 2006-08-11 12:00 | 163 | 6.1d | 0d | GWT Analista 1; GWT Operaciones 1 | 32h |
| 169 | WBS_M_01.1.48.145.7 | Pantalla de despliegue de selecciones con fotos blogueables | 4h | 2006-08-11 13:00 | 2006-08-11 17:00 | 168 | 6.1d |  | GWT Analista 2 | 4h |
| 170 | WBS_M_01.1.48.153 | **Compartir: Selecciones** | 6d | 2006-08-08 13:00 | 2006-08-16 12:00 | 137 | 3.6d |  |  | 80h |
| 171 | WBS_M_01.1.48.153.1 | Definición de L&F | 8h | 2006-08-08 13:00 | 2006-08-09 12:00 |  | 3.6d | 0d | DC Diseñador 1 | 8h |
| 172 | WBS_M_01.1.48.153.2 | Mecanismo para compartir selecciones a imagen y semejanza de compartir de carpetas en PHS. | 16h | 2006-08-09 13:00 | 2006-08-11 12:00 | 171 | 3.6d | 0d | GWT Lider Proyecto; GWT Analista 1 | 32h |
| 173 | WBS_M_01.1.48.153.3 | Visualización de selecciones que he compartido. Filtros: compartidas por contactos, públicas, privadas. | 24h | 2006-08-11 13:00 | 2006-08-16 12:00 | 172 | 3.6d |  | GWT Lider Proyecto | 24h |
| 174 | WBS_M_01.1.48.153.4 | Incluir invitación a contacto no registrado cuando se comparte | 4h | 2006-08-11 13:00 | 2006-08-11 17:00 | 172 | 6.1d |  | GWT Lider Proyecto | 4h |
| 175 | WBS_M_01.1.48.153.5 | **Notificación de cambios en blogs compartidos** | 1d | 2006-08-11 13:00 | 2006-08-14 12:00 | 171, 172 | 5.6d |  |  | 12h |
| 176 | WBS_M_01.1.48.153.5.1 | Almacenar fecha de modificación de blog. | 4h | 2006-08-11 13:00 | 2006-08-11 17:00 |  | 5.6d | 0d | GWT Analista 2 | 4h |
| 177 | WBS_M_01.1.48.153.5.2 | Almacenar fecha de última visita de un contacto al blog. Estudiar mecanismo | 4h | 2006-08-11 13:00 | 2006-08-11 17:00 |  | 5.6d | 0d | GWT Analista 2 | 4h |
| 178 | WBS_M_01.1.48.153.5.3 | Indicación de modificación de un blog desde la última visita | 4h | 2006-08-14 08:00 | 2006-08-14 12:00 | 176, 177 | 5.6d |  | GWT Analista 1 | 4h |
| 179 | WBS_M_01.1.48.162 | Compartir: Proyectos Revisar mecanismo actual | 8h | 2006-08-11 08:48 | 2006-08-14 08:48 | 83 | 6d |  | GWT Lider Proyecto | 8h |
| 180 | WBS_M_01.1.48.163 | **Búsqueda de fotos** | 1d | 2006-08-08 13:00 | 2006-08-09 12:00 | 137 | 8.6d |  |  | 16h |
| 181 | WBS_M_01.1.48.163.1 | Búsqueda de fotos por tag en la cabecera de Mi Dichis | 8h | 2006-08-08 13:00 | 2006-08-09 12:00 |  | 8.6d |  | GWT Analista 1 | 8h |
| 182 | WBS_M_01.1.48.163.2 | Búsqueda avanzada utilizando: fecha, usuario, palabras clave, descripción, tamaños, tipo, resolución, precio, metadata. | 8h | 2006-08-08 13:00 | 2006-08-09 12:00 |  | 8.6d |  | GWT Analista 1 | 8h |
| 183 | WBS_M_01.1.48.166 | Ampliación de estadísticas (BO) Productos por categorías por partner | 4h | 2006-08-18 08:48 | 2006-08-18 13:48 | 122 | 1.5d |  | GWT Analista 2 | 4h |

| ID | WBS | Task | Duration | Start | Finish | Predecessors | Total slack | Resources | Work |
| --- | --- | --- | --- | --- | --- | --- | --- | --- | --- |
| 184 | WBS_M_01.1.48.167 | **Enlatados** | 1.5d | 2006-07-14 10:00 | 2006-07-17 15:00 | 23 | 25.35d |  | 48h |
| 185 | WBS_M_01.1.48.167.1 | Revisión de envío de correos automáticos | 8h | 2006-07-14 10:00 | 2006-07-17 10:00 |  | 25.85d | GWT Lider Proyecto; TN Lider Proyecto; DC Lider Proyecto | 24h |
| 186 | WBS_M_01.1.48.167.2 | Definición de correos (enlatados) _idi | 12h | 2006-07-14 10:00 | 2006-07-17 15:00 |  | 25.35d | TN Lider Proyecto; DC Lider Proyecto | 24h |
| 187 | WBS_M_01.1.218 | **Implantación** | 13d | 2006-08-22 08:48 | 2006-09-08 08:48 | 17 | 0d |  | 312h |
| 188 | WBS_M_01.1.218.1 | Entrenamiento al usuario | 8h | 2006-08-22 08:48 | 2006-08-23 08:48 |  | 0d | TN Lider Proyecto | 8h |
| 189 | WBS_M_01.1.218.2 | Definición de templates para puesta al aire | 16h | 2006-08-23 08:48 | 2006-08-25 08:48 | 188 | 0d | TN Lider Proyecto; DC Lider Proyecto | 32h |
| 190 | WBS_M_01.1.218.3 | Migración a ambiente de producción | 8h | 2006-08-22 08:48 | 2006-08-23 08:48 |  | 2d | GWT Lider Proyecto; GWT Analista 1; GWT Analista 2; GWT Operaciones 1 | 32h |
| 191 | WBS_M_01.1.218.4 | Pruebas en ambiente de producción | 40h | 2006-08-25 08:48 | 2006-09-01 08:48 | 189, 190 | 0d | GWT Lider Proyecto; GWT Analista 1; GWT Analista 2 | 120h |
| 192 | WBS_M_01.1.218.5 | Ajustes tras pruebas en producción | 40h | 2006-09-01 08:48 | 2006-09-08 08:48 | 191 | 0d | GWT Lider Proyecto; GWT Analista 1; GWT Analista 2 | 120h |
| 193 | WBS_M_01.1.224 | **Documentación** | 6.25d | 2006-09-08 08:48 | 2006-09-18 10:48 | 187 | 0d |  | 250h |
| 194 | WBS_M_01.1.224.1 | Manual de usuario | 50h | 2006-09-08 08:48 | 2006-09-18 10:48 |  | 0d | TN Lider Proyecto; DC Lider Proyecto | 100h |
| 195 | WBS_M_01.1.224.3 | Documentación técnica | 50h | 2006-09-08 08:48 | 2006-09-18 10:48 |  | 0d | GWT Lider Proyecto; GWT Analista 1; GWT Analista 2 | 150h |
