# Planning DiChis

Schedule from MS Project, 2006-07-03 to 2006-11-22.
GWT

## Calendars

- Standard: Mon-Fri 08:00-12:00, 13:00-17:00; Sat-Sun off. Exceptions (off unless hours are given): 2006-08-27 08:00-12:00, 13:00-17:00.

## Resources

| Resource |
| --- |
| GWT Socio |
| GWT Lider Proyecto |
| TN Lider Proyecto |
| GWT Analista 1 |
| GWT Analista 2 |
| DC Lider Proyecto |
| TN Operaciones 1 |
| GWT Operaciones 1 |
| DC Diseñador 1 |
| GWT Programador 1 |
| GWT Programador 2 |

## Schedule

| ID | WBS | Task | Duration | Start | Finish | Predecessors | Total slack | Free slack | Constraint | Resources | Work |
| --- | --- | --- | --- | --- | --- | --- | --- | --- | --- | --- | --- |
| 1 | DC-1 | **Proyecto DiChis** | 103.25d | 2006-07-03 08:00 | 2006-11-22 10:00 |  | 0d |  |  |  | 2875.41h |
| 2 | DC-1.1 | Gerencia de Proyectos | 820h | 2006-07-03 08:00 | 2006-11-21 12:00 |  | 0.75d |  |  | GWT Socio [10%]; GWT Lider Proyecto [10%]; TN Lider Proyecto [10%] | 183.1h |
| 3 | DC-1.2 | **Pruebas en ambiente de desarrollo** | 102.5d | 2006-07-03 08:00 | 2006-11-21 12:00 |  | 0.75d |  |  |  | 484.8h |
| 4 | DC-1.2.1 | Internas | 820h | 2006-07-03 08:00 | 2006-11-21 12:00 |  | 0.75d |  |  | GWT Lider Proyecto [10%]; GWT Analista 1 [10%]; GWT Analista 2 [10%] | 150.8h |
| 5 | DC-1.2.2 | De certificación | 820h | 2006-07-03 08:00 | 2006-11-21 12:00 |  | 0.75d |  |  | TN Lider Proyecto [10%]; DC Lider Proyecto [10%] | 164h |
| 6 | DC-1.2.3 | Ajustes tras pruebas | 820h | 2006-07-03 08:00 | 2006-11-21 12:00 |  | 0.75d |  |  | GWT Lider Proyecto [10%]; GWT Analista 1 [10%]; GWT Analista 2 [10%] | 170h |
| 7 | DC-1.3 | **Operación, Mantenimiento y Soporte** | 7d | 2006-07-03 08:00 | 2006-07-11 17:00 |  | 5d | 0d |  |  | 44.34h |
| 8 | DC-1.3.1 | Actualización de documento de configuración de servidores | 2h | 2006-07-03 08:00 | 2006-07-03 10:00 |  | 6.75d | 0d |  | GWT Socio [5%]; TN Operaciones 1 [75%]; GWT Operaciones 1 [75%] | 3.1h |
| 9 | DC-1.3.2 | Adquisición de servicios de hosting | 8h | 2006-07-03 10:00 | 2006-07-04 10:00 | 8 | 6.75d | 0d |  | DC Lider Proyecto [90%] | 7.2h |
| 10 | DC-1.3.3 | Adquisición e Instalación de PDFlib | 4h | 2006-07-04 10:00 | 2006-07-04 15:00 | 9 | 7.25d | 0d |  | GWT Socio [2%]; GWT Operaciones 1 [75%] | 3.08h |
| 11 | DC-1.3.4 | Configuración y prueba de PDFLib | 4h | 2006-07-04 15:00 | 2006-07-05 10:00 | 10 | 7.25d | 0d |  | GWT Operaciones 1 [75%] | 3h |
| 12 | DC-1.3.5 | Instalación de N2C y WIB | 8h | 2006-07-05 10:00 | 2006-07-06 10:00 | 11 | 7.25d | 0d |  | GWT Operaciones 1 [75%] | 6h |
| 13 | DC-1.3.6 | Instalación de librerias de manipulación de imágenes (Image Magick y GD) | 4h | 2006-07-06 10:00 | 2006-07-06 15:00 | 12 | 7.25d | 0d |  | GWT Operaciones 1 [75%] | 3h |
| 14 | DC-1.3.7 | Investigación y Adquisición de versión JAVA de Aurigma | 8h | 2006-07-10 08:00 | 2006-07-10 17:00 | 9 | 3d | 0d | start no earlier than 2006-07-10 08:00 | GWT Socio [2%]; GWT Lider Proyecto [80%] | 6.56h |
| 15 | DC-1.3.8 | Configuración y pruebas versión Java de Aurigma | 8h | 2006-07-11 08:00 | 2006-07-11 17:00 | 14 | 3d |  |  | GWT Lider Proyecto [80%] | 6.4h |
| 16 | DC-1.3.9 | Limpieza del URL para eliminar ZZZ/…/… | 8h | 2006-07-06 15:00 | 2006-07-07 15:00 | 13 | 7.25d |  |  | GWT Operaciones 1 [75%] | 6h |
| 17 | DC-1.4 | **Desarrollo** | 77d | 2006-07-12 08:00 | 2006-10-25 17:00 | 7 | 0d |  |  |  | 1646.57h |
| 18 | DC-1.4.1 | **Migración BD PHS a Servidor de desarrollo** | 4d | 2006-07-12 08:00 | 2006-07-17 17:00 |  | 3d | 0d |  |  | 36.8h |
| 19 | DC-1.4.1.1 | Reingeniería del Modelo de datos de BD incorporando ajustes para manejo de selecciones y blogs. | 8h | 2006-07-12 08:00 | 2006-07-12 17:00 |  | 5d | 2d |  | GWT Lider Proyecto; GWT Analista 1 | 16h |
| 20 | DC-1.4.1.2 | Planificación de la migración | 4h | 2006-07-13 08:00 | 2006-07-13 12:00 |  | 4.5d | 1.5d | start no earlier than 2006-07-13 08:00 | GWT Lider Proyecto; GWT Analista 1 | 8h |
| 21 | DC-1.4.1.3 | Creación de tablas N2C a imagen de PHS con los cambios. OJO: e-MM Català en TRADUCCIONES | 8h | 2006-07-17 08:00 | 2006-07-17 17:00 | 20, 19 | 3d |  | start no earlier than 2006-07-13 08:00 | GWT Analista 2 [20%] | 1.6h |
| 22 | DC-1.4.1.4 | Traducción de términos $MM. Manejo de catalán, español e inglés en principio | 8h | 2006-07-12 08:00 | 2006-07-12 17:00 |  | 6d |  |  | DC Lider Proyecto [90%]; TN Lider Proyecto [50%] | 11.2h |
| 23 | DC-1.4.2 | **Migración aplicación PHS** | 5d | 2006-07-17 17:00 | 2006-07-24 17:00 | 18 | 3d | 0d |  |  | 104h |
| 24 | DC-1.4.2.1 | Construcción de mapa de navegación de PHS | 8h | 2006-07-17 17:00 | 2006-07-18 17:00 |  | 3d | 0d | start no earlier than 2006-07-16 08:00 | GWT Lider Proyecto; GWT Analista 1; GWT Analista 2 | 16h |
| 25 | DC-1.4.2.2 | Casos de Uso PHS | 8h | 2006-07-19 08:00 | 2006-07-19 17:00 | 24 | 3d | 0d | start no earlier than 2006-07-19 08:00 | GWT Lider Proyecto; GWT Analista 1; GWT Analista 2 | 24h |
| 26 | DC-1.4.2.3 | Adaptación de Casos de Uso PHS incorporando DiChis | 16h | 2006-07-20 08:00 | 2006-07-21 17:00 | 25 | 3d | 0d | start no earlier than 2006-07-20 08:00 | GWT Lider Proyecto; GWT Analista 1; GWT Analista 2 | 48h |
| 27 | DC-1.4.2.4 | Pantalla de unificación de funcionalidades de back office -al estilo WIB- Start page | 8h | 2006-07-24 08:00 | 2006-07-24 17:00 | 26 | 6.25d |  | start no earlier than 2006-07-16 08:00 | GWT Analista 1 | 8h |
| 28 | DC-1.4.2.5 | Verificación de funcionalidades de B.O. que se pueden probar hasta este punto. | 8h | 2006-07-24 08:00 | 2006-07-24 17:00 | 26 | 3d |  |  | GWT Analista 2 | 8h |

| ID | WBS | Task | Duration | Start | Finish | Predecessors | Total slack | Free slack | Constraint | Resources | Work |
| --- | --- | --- | --- | --- | --- | --- | --- | --- | --- | --- | --- |
| 29 | DC-1.4.3 | **Revisión y ajuste de programas recurrentes** | 2d | 2006-07-25 08:00 | 2006-07-26 17:00 | 23 | 66d |  |  |  | 16h |
| 30 | DC-1.4.3.1 | arriba | 4h | 2006-07-25 08:00 | 2006-07-25 12:00 |  | 66d | 0d |  | GWT Lider Proyecto | 4h |
| 31 | DC-1.4.3.2 | cabecera | 8h | 2006-07-25 13:00 | 2006-07-26 12:00 | 30 | 66d | 0d |  | GWT Lider Proyecto | 8h |
| 32 | DC-1.4.3.3 | pie | 4h | 2006-07-26 13:00 | 2006-07-26 17:00 | 31 | 66d |  |  | GWT Lider Proyecto | 4h |
| 33 | DC-1.4.4 | Definición de L&F Lineamientos a seguir en el site (reglas generales) | 8h | 2006-07-12 08:00 | 2006-07-12 17:00 |  | 76d |  | start no earlier than 2006-07-02 08:00 | DC Diseñador 1 | 8h |
| 34 | DC-1.4.5 | **Ajuste de páginas de contenido** | 6d | 2006-07-25 08:00 | 2006-08-01 17:00 | 23 | 62d |  |  |  | 51.6h |
| 35 | DC-1.4.5.1 | Definición de L&F para páginas de contenido | 8h | 2006-07-25 08:00 | 2006-07-25 17:00 |  | 62.75d | 0d |  | DC Diseñador 1 | 8h |
| 36 | DC-1.4.5.2 | Ajuste de L&F para páginas de contenido | 10h | 2006-07-26 08:00 | 2006-07-27 10:00 | 35 | 62.75d | 0.75d |  | GWT Programador 1 | 10h |
| 37 | DC-1.4.5.3 | Actualización del contenido (ver anexo). Considerar mecanismo para multiidioma | 24h | 2006-07-28 08:00 | 2006-08-01 17:00 | 36 | 62d |  | start no earlier than 2006-07-28 08:00 | TN Lider Proyecto [50%]; DC Lider Proyecto [90%] | 33.6h |
| 38 | DC-1.4.6 | **Ajuste de páginas con párrafos de aplicación** | 6d | 2006-07-27 08:00 | 2006-08-03 17:00 | 23 | 6d |  |  |  | 27.4h |
| 39 | DC-1.4.6.1 | Definición de L&F para páginas con aplicación | 8h | 2006-07-27 08:00 | 2006-07-27 17:00 |  | 6d | 0d | start no earlier than 2006-07-27 08:00 | DC Diseñador 1 | 8h |
| 40 | DC-1.4.6.2 | Ajuste de L&F para páginas con aplicación | 10h | 2006-07-28 08:00 | 2006-07-31 10:00 | 39 | 6d | 0d |  | GWT Programador 2 [50%] | 5h |
| 41 | DC-1.4.6.3 | Revisión FAQ, Boletin | 8h | 2006-07-31 10:00 | 2006-08-01 10:00 | 40 | 62.75d |  |  | GWT Programador 2 | 8h |
| 42 | DC-1.4.6.4 | Revisión de registro de usuarios | 8h | 2006-08-03 08:00 | 2006-08-03 17:00 | 40, 45 | 3.25d | 0d |  | GWT Lider Proyecto [80%] | 6.4h |
| 43 | DC-1.4.7 | **Módulo de Admin de Cliente (MAC)** | 4d | 2006-07-28 08:00 | 2006-08-02 17:00 | 23 | 3.25d |  |  |  | 64h |
| 44 | DC-1.4.7.1 | Definición de L&F MAC | 8h | 2006-07-28 08:00 | 2006-07-28 17:00 |  | 3.25d | 0d | start no earlier than 2006-07-28 08:00 | DC Diseñador 1 | 8h |
| 45 | DC-1.4.7.2 | Ajuste de L&F MAC | 24h | 2006-07-31 08:00 | 2006-08-02 17:00 | 44 | 3.25d | 0d |  | GWT Lider Proyecto | 24h |
| 46 | DC-1.4.8 | **Upload de fotos** | 6.75d | 2006-07-31 08:00 | 2006-08-08 15:00 | 23 | 3.25d | 0d |  |  | 29.82h |
| 47 | DC-1.4.8.1 | Definición de L&F Upload | 8h | 2006-07-31 08:00 | 2006-07-31 17:00 |  | 8d | 4.75d | start no earlier than 2006-07-31 08:00 | DC Diseñador 1 | 8h |
| 48 | DC-1.4.8.2 | Incorporación de Upload Aurigma en versión java. Considerar tiempo de investigación. | 6h | 2006-08-04 08:00 | 2006-08-04 15:00 | 42 | 3.25d | 0d | start no earlier than 2006-08-03 08:00 | GWT Lider Proyecto; GWT Analista 1 [80%] | 9.42h |
| 49 | DC-1.4.8.3 | Desactivar botón de envío por espacio insuficiente. | 2h | 2006-08-04 15:00 | 2006-08-04 17:00 | 48 | 5d |  |  | GWT Lider Proyecto | 2h |
| 50 | DC-1.4.8.4 | Extraer metadata de las fotos al momento de la subida y asociarla al registro de la foto en BD (requiere investigación) | 8h | 2006-08-04 15:00 | 2006-08-07 15:00 | 48 | 3.25d | 0d |  | GWT Analista 1 [80%] | 6.4h |
| 51 | DC-1.4.8.5 | Ajuste de L&F (versión java y tradicional) | 8h | 2006-08-07 15:00 | 2006-08-08 15:00 | 47, 50 | 3.25d |  | start no earlier than 2006-07-27 08:00 | GWT Programador 2 [50%] | 4h |
| 52 | DC-1.4.9 | **Administración de Carpetas** | 4.25d | 2006-08-08 15:00 | 2006-08-14 17:00 | 46 | 3d |  |  |  | 58.4h |
| 53 | DC-1.4.9.1 | Definición de L&F Admin Carpetas | 8h | 2006-08-08 15:00 | 2006-08-09 15:00 |  | 4.25d | 1.25d | start no earlier than 2006-08-02 08:00 | DC Diseñador 1 | 8h |
| 54 | DC-1.4.9.2 | Revisión de opciones de administración de carpetas: renombrar carpeta, cambiar portada, copiar carpeta, eliminar carpeta | 8h | 2006-08-08 15:00 | 2006-08-09 15:00 |  | 3.25d | 0.25d | start no earlier than 2006-08-08 08:00 | GWT Lider Proyecto | 8h |
| 55 | DC-1.4.9.3 | Verificación de nombre de carpeta física versus nombre interno para evitar aborto de mkdir | 8h | 2006-08-10 08:00 | 2006-08-10 17:00 | 54 | 3d | 0d | start no earlier than 2006-08-10 08:00 | GWT Lider Proyecto [80%] | 6.4h |
| 56 | DC-1.4.9.4 | Eliminación de opción de compartir a nivel de carpeta | 4h | 2006-08-08 15:00 | 2006-08-09 10:00 |  | 4.25d | 0.75d |  | GWT Analista 1 | 4h |
| 57 | DC-1.4.9.5 | Ajuste de L&F Admin Carpetas | 16h | 2006-08-11 08:00 | 2006-08-14 17:00 | 53, 55 | 3d | 0d | start no earlier than 2006-08-11 08:00 | GWT Lider Proyecto; GWT Programador 2 | 32h |

| ID | WBS | Task | Duration | Start | Finish | Predecessors | Total slack | Free slack | Constraint | Resources | Work |
| --- | --- | --- | --- | --- | --- | --- | --- | --- | --- | --- | --- |
| 58 | DC-1.4.10 | **Administración de imágenes en carpetas** | 10.75d | 2006-08-08 15:00 | 2006-08-23 12:00 | 46 | 4.75d |  |  |  | 76.8h |
| 59 | DC-1.4.10.1 | Definición de L&F Imágenes en Carpetas | 8h | 2006-08-08 15:00 | 2006-08-09 15:00 |  | 54.25d | 2.25d | start no earlier than 2006-08-07 08:00 | DC Diseñador 1 | 8h |
| 60 | DC-1.4.10.2 | Visualización de fotos: tamaño de visualización más grande, mostrar descripción de la foto. | 16h | 2006-08-10 08:00 | 2006-08-11 17:00 | 56 | 3.5d | 0d | start no earlier than 2006-08-10 08:00 | GWT Analista 1 [80%] | 12.8h |
| 61 | DC-1.4.10.3 | Revisión de opciones de administración de imágenes: renombrar imagen, copiar imagen, mover imagen, eliminar imagen, editar imagen. | 8h | 2006-08-15 08:00 | 2006-08-15 17:00 | 60, 57 | 3d | 0d | start no earlier than 2006-08-15 08:00 | GWT Lider Proyecto | 8h |
| 62 | DC-1.4.10.4 | **Detalle de foto** | 5.5d | 2006-08-16 08:00 | 2006-08-23 12:00 | 60 | 0d |  |  |  | 16h |
| 63 | DC-1.4.10.4.1 | Edición de datos de foto | 8h | 2006-08-16 08:00 | 2006-08-16 17:00 | 61 | 3d | 0d | start no earlier than 2006-08-16 08:00 | GWT Lider Proyecto [80%] | 6.4h |
| 64 | DC-1.4.10.4.2 | Descarga de foto original | 2h | 2006-08-22 08:00 | 2006-08-22 10:00 | 63 | 0d |  | start no earlier than 2006-08-22 08:00 | GWT Lider Proyecto [80%] | 1.6h |
| 65 | DC-1.4.10.4.3 | Click sobre foto lleva a edición avanzada | 2h | 2006-08-22 10:00 | 2006-08-22 12:00 | 64 | 0d |  | start no earlier than 2006-08-22 08:00 | GWT Lider Proyecto [80%] | 1.6h |
| 66 | DC-1.4.10.4.4 | Incluir metadata en datos de foto desplegada | 8h | 2006-08-22 13:00 | 2006-08-23 12:00 | 65 | 0d |  | start no earlier than 2006-08-22 08:00 | GWT Lider Proyecto [80%] | 6.4h |
| 67 | DC-1.4.10.5 | Ajuste de L&F Admin Imágenes en Carpetas | 16h | 2006-08-14 08:00 | 2006-08-15 17:00 | 59, 60 | 52d |  |  | GWT Programador 1; GWT Analista 1 | 32h |
| 68 | DC-1.4.11 | **Edición de imágenes** | 4d | 2006-08-14 08:00 | 2006-08-17 17:00 | 60 | 3.5d | 0d |  |  | 40h |
| 69 | DC-1.4.11.1 | Definición de L&F Edición Imágenes | 8h | 2006-08-14 08:00 | 2006-08-14 17:00 |  | 3.5d | 0d | start no earlier than 2006-08-07 08:00 | DC Diseñador 1 | 8h |
| 70 | DC-1.4.11.2 | Revisión de edición avanzada de fotos: Ojos rojos, Rotación, Efectos -blanco y negro / sepia- | 8h | 2006-08-17 08:00 | 2006-08-17 17:00 | 63 | 3.5d |  | start no earlier than 2006-08-16 08:00 | GWT Lider Proyecto | 8h |
| 71 | DC-1.4.11.3 | Ajuste de L&F Edición Imágenes | 24h | 2006-08-15 08:00 | 2006-08-17 17:00 | 69 | 3.5d |  |  | GWT Analista 2 | 24h |
| 72 | DC-1.4.12 | **Administración de cuenta del cliente** | 22d | 2006-07-31 08:00 | 2006-08-28 17:00 | 23 | 42d |  |  |  | 32h |
| 73 | DC-1.4.12.1 | Definición de L&F Cuenta Cliente | 8h | 2006-07-31 08:00 | 2006-07-31 17:00 |  | 60d | 18d | start no earlier than 2006-07-31 08:00 | DC Diseñador 1 | 8h |
| 74 | DC-1.4.12.2 | Ajuste de L&F Cuenta Cliente | 16h | 2006-08-25 08:00 | 2006-08-27 17:00 | 73 | 42d | 0d | start no earlier than 2006-08-25 08:00 | GWT Programador 1 | 16h |
| 75 | DC-1.4.12.3 | Revisión de administración de cuenta del cliente | 8h | 2006-08-28 08:00 | 2006-08-28 17:00 | 74 | 42d |  |  | GWT Programador 1 | 8h |
| 76 | DC-1.4.13 | **Libreta de contactos** | 29d | 2006-07-27 08:00 | 2006-09-04 17:00 | 23 | 20d |  |  |  | 72h |
| 77 | DC-1.4.13.1 | Definición de L&F Libreta | 8h | 2006-08-03 08:00 | 2006-08-03 17:00 |  | 56.5d | 19.5d | start no earlier than 2006-08-03 08:00 | DC Diseñador 1 | 8h |
| 78 | DC-1.4.13.2 | Ajustes de L&F Libreta | 24h | 2006-08-30 13:00 | 2006-09-04 12:00 | 77, 100 | 37d | 0d | start no earlier than 2006-08-29 08:00 | GWT Analista 2 | 24h |
| 79 | DC-1.4.13.3 | Detectar que un agregado a la libreta de contactos está registrado y permitir incluirlo en un grupo | 4h | 2006-09-04 13:00 | 2006-09-04 17:00 | 78 | 37d |  | start no earlier than 2006-09-01 08:00 | GWT Analista 2 | 4h |
| 80 | DC-1.4.13.4 | Invitar a dichis.com | 8h | 2006-07-27 08:00 | 2006-07-27 17:00 |  | 65d |  | start no earlier than 2006-07-27 08:00 | GWT Lider Proyecto; GWT Programador 1 | 16h |
| 81 | DC-1.4.13.5 | Visualización, edición, creación y eliminación de un grupo (Detalle grupo) | 12h | 2006-07-28 08:00 | 2006-07-31 12:00 |  | 19d | 0d | start no earlier than 2006-07-28 08:00 | GWT Analista 1 | 12h |
| 82 | DC-1.4.13.6 | Visualización, edición, creación y eliminación de Mis grupos | 8h | 2006-07-31 13:00 | 2006-08-01 12:00 | 81 | 19d | 0d |  | GWT Analista 1 | 8h |

| ID | WBS | Task | Duration | Start | Finish | Predecessors | Total slack | Free slack | Constraint | Resources | Work |
| --- | --- | --- | --- | --- | --- | --- | --- | --- | --- | --- | --- |
| 83 | DC-1.4.14 | **Proyectos** | 18d | 2006-08-18 08:00 | 2006-09-11 17:00 | 68 | 3.5d | 0d |  |  | 267.05h |
| 84 | DC-1.4.14.1 | **Albumes** | 14.5d | 2006-08-23 13:00 | 2006-09-11 17:00 |  | 0d |  |  |  | 112h |
| 85 | DC-1.4.14.1.1 | Reconsiderar L&F en Albumes | 48h | 2006-08-23 13:00 | 2006-08-31 12:00 | 66 | 0d |  |  | GWT Lider Proyecto [90%] | 43.2h |
| 86 | DC-1.4.14.1.2 | Revisión de funcionalidad de Albumes | 24h | 2006-08-31 13:00 | 2006-09-05 12:00 | 85 | 0d |  |  | GWT Lider Proyecto | 24h |
| 87 | DC-1.4.14.1.3 | Revisión de proceso de construcción del album. | 24h | 2006-09-05 13:00 | 2006-09-08 12:00 | 86 | 0d |  |  | GWT Lider Proyecto | 24h |
| 88 | DC-1.4.14.1.4 | Pruebas de imprenta | 8h | 2006-09-08 13:00 | 2006-09-11 12:00 | 87 | 0d |  |  | GWT Lider Proyecto; DC Lider Proyecto [90%]; TN Lider Proyecto [50%] | 16.8h |
| 89 | DC-1.4.14.1.5 | Consideraciones de estampillado de productos | 2h | 2006-09-11 13:00 | 2006-09-11 15:00 | 88 | 0d |  |  | GWT Lider Proyecto | 2h |
| 90 | DC-1.4.14.1.6 | Información adicional a ser incluida en el PDF o txt. Ejemplo: carta al usuario, etiqueta para el sobre ,etc. | 2h | 2006-09-11 15:00 | 2006-09-11 17:00 | 89 | 0d |  |  | GWT Lider Proyecto | 2h |
| 91 | DC-1.4.14.2 | **Postales** | 4d | 2006-08-18 08:00 | 2006-08-23 17:00 |  | 4d |  |  |  | 31.55h |
| 92 | DC-1.4.14.2.1 | Reconsiderar L&F en Postales | 16h | 2006-08-18 08:00 | 2006-08-21 17:00 |  | 4d | 0d | start no earlier than 2006-08-15 08:00 | GWT Analista 1 | 16h |
| 93 | DC-1.4.14.2.2 | Revisión de funcionalidad de Postales | 8h | 2006-08-22 08:00 | 2006-08-22 17:00 | 92 | 4d | 0d |  | GWT Analista 1 | 8h |
| 94 | DC-1.4.14.2.3 | Pruebas de imprenta | 8h | 2006-08-23 08:00 | 2006-08-23 17:00 | 93 | 14d |  |  | GWT Lider Proyecto [5%]; DC Lider Proyecto [40%]; TN Lider Proyecto [25%] | 3.55h |
| 95 | DC-1.4.14.2.4 | Consideraciones de estampillado de productos | 2h | 2006-08-23 08:00 | 2006-08-23 10:00 | 93 | 4d | 0d |  | GWT Analista 1 | 2h |
| 96 | DC-1.4.14.2.5 | Información adicional a ser incluida en el PDF o txt. Ejemplo: carta al usuario, etiqueta para el sobre ,etc. | 2h | 2006-08-23 10:00 | 2006-08-23 12:00 | 95 | 4d | 0d |  | GWT Analista 1 | 2h |
| 97 | DC-1.4.14.3 | **Regalos** | 9.5d | 2006-08-18 08:00 | 2006-08-30 12:00 |  | 16.5d |  |  |  | 41.2h |
| 98 | DC-1.4.14.3.1 | Reconsiderar L&F en Regalos | 16h | 2006-08-18 08:00 | 2006-08-21 17:00 |  | 21.5d | 5d |  | GWT Analista 2 | 16h |
| 99 | DC-1.4.14.3.2 | Revisión de funcionalidad de Regalos | 8h | 2006-08-28 08:00 | 2006-08-28 17:00 | 98 | 16.5d | 0d | start no earlier than 2006-08-28 08:00 | GWT Analista 2 | 8h |
| 100 | DC-1.4.14.3.3 | Pruebas de imprenta | 8h | 2006-08-29 13:00 | 2006-08-30 12:00 | 102 | 16.5d | 0d |  | GWT Analista 2; DC Lider Proyecto [40%]; TN Lider Proyecto [25%] | 13.2h |
| 101 | DC-1.4.14.3.4 | Consideraciones de estampillado de productos | 2h | 2006-08-29 08:00 | 2006-08-29 10:00 | 99 | 16.5d | 0d |  | GWT Analista 2 | 2h |
| 102 | DC-1.4.14.3.5 | Información adicional a ser incluida en el PDF o txt. Ejemplo: carta al usuario, etiqueta para el sobre ,etc. | 2h | 2006-08-29 10:00 | 2006-08-29 12:00 | 101 | 16.5d | 0d | start no earlier than 2006-08-22 08:00 | GWT Analista 2 | 2h |
| 103 | DC-1.4.14.4 | **Gigantografías** | 15d | 2006-08-18 08:00 | 2006-09-06 17:00 |  | 8.5d |  |  |  | 82.3h |
| 104 | DC-1.4.14.4.1 | Definición L&F Gigantografías | 8h | 2006-08-18 08:00 | 2006-08-18 17:00 |  | 8.5d | 4.5d |  | DC Diseñador 1 | 8h |
| 105 | DC-1.4.14.4.2 | **Construcción de programa de pasos para elaboración de las gigantografías** | 8d | 2006-08-25 13:00 | 2006-09-05 12:00 | 104 | 3d | 0d |  |  | 60.8h |
| 106 | DC-1.4.14.4.2.1 | Pantalla de selección de material, medida y acabado | 24h | 2006-08-25 13:00 | 2006-08-29 12:00 | 115 | 3d | 0d |  | GWT Lider Proyecto [10%]; GWT Analista 1 | 17.6h |
| 107 | DC-1.4.14.4.2.2 | Pantalla de construcción de gigantografías a partir de templates | 40h | 2006-08-29 13:00 | 2006-09-05 12:00 | 106 | 3d | 0d |  | GWT Lider Proyecto [10%]; GWT Analista 1 | 43.2h |

Notes:
- 87: Revisión de proceso de construcción del album. Considerar que una foto al ser seleccionada no debe desincorporarse del carrusel sino que debe ser marcada, de modo tal que pueda utilizarse en múltiples ocasiones

| ID | WBS | Task | Duration | Start | Finish | Predecessors | Total slack | Free slack | Constraint | Resources | Work |
| --- | --- | --- | --- | --- | --- | --- | --- | --- | --- | --- | --- |
| 108 | DC-1.4.14.4.3 | **Construcción de PDF. Conexión con servidor de Mulá** | 0.5d | 2006-09-05 13:00 | 2006-09-05 17:00 | 105 | 3d | 0d |  |  | 2.3h |
| 109 | DC-1.4.14.4.3.1 | Consideraciones de estampillado de productos | 2h | 2006-09-05 13:00 | 2006-09-05 15:00 |  | 3d | 0d |  | GWT Lider Proyecto [5%]; GWT Analista 2 | 1.1h |
| 110 | DC-1.4.14.4.3.2 | Información adicional a ser incluida en el PDF o txt. Ejemplo: carta al usuario, etiqueta para el sobre ,etc. | 2h | 2006-09-05 15:00 | 2006-09-05 17:00 | 109 | 3d |  |  | GWT Lider Proyecto [10%]; GWT Analista 2 | 1.2h |
| 111 | DC-1.4.14.4.4 | Pruebas de imprenta | 8h | 2006-09-06 08:00 | 2006-09-06 17:00 | 108 | 3d |  |  | GWT Lider Proyecto [10%]; DC Lider Proyecto [80%]; TN Lider Proyecto [50%] | 11.2h |
| 112 | DC-1.4.15 | **Fotos sueltas (Quick shop)** | 18d | 2006-08-01 13:00 | 2006-08-25 12:00 |  | 4d |  |  |  | 32h |
| 113 | DC-1.4.15.1 | Consideración de acabado mate y brillante | 8h | 2006-08-01 13:00 | 2006-08-02 12:00 | 82 | 19d | 15d |  | GWT Analista 1 | 8h |
| 114 | DC-1.4.15.2 | Definición de L&F Quickshop | 8h | 2006-08-18 08:00 | 2006-08-18 17:00 |  | 6.5d | 2.5d | start no earlier than 2006-08-18 08:00 | DC Diseñador 1 | 8h |
| 115 | DC-1.4.15.3 | Ajuste de L&F Quickshop | 16h | 2006-08-23 13:00 | 2006-08-25 12:00 | 114, 113, 96 | 4d | 0d | start no earlier than 2006-08-15 08:00 | GWT Analista 1 | 16h |
| 116 | DC-1.4.16 | **Colecciones de Partners** | 11d | 2006-09-12 08:00 | 2006-09-26 17:00 | 83 | 0d |  |  |  | 38.4h |
| 117 | DC-1.4.16.1 | Definición de L&F Partners | 8h | 2006-09-12 08:00 | 2006-09-12 17:00 |  | 8d |  |  | DC Diseñador 1 | 8h |
| 118 | DC-1.4.16.2 | **Galería de Foto Mulà (sin descarga de originales)** | 2d | 2006-09-25 08:00 | 2006-09-26 17:00 | 117 | 0d |  |  |  | 30.4h |
| 119 | DC-1.4.16.2.1 | Visualización de Galería de Foto Mulà | 8h | 2006-09-25 08:00 | 2006-09-25 17:00 |  | 0d |  | start no earlier than 2006-09-25 08:00 | GWT Lider Proyecto; GWT Analista 2 [80%] | 14.4h |
| 120 | DC-1.4.16.2.2 | Ajuste de programas para la selección de fotos para utilizar en productos | 8h | 2006-09-26 08:00 | 2006-09-26 17:00 | 119 | 0d |  |  | GWT Lider Proyecto; GWT Analista 2 | 16h |
| 121 | DC-1.4.17 | Ajuste de L&F Partners | 4h | 2006-09-27 08:00 | 2006-09-27 12:00 | 118 | 0d |  |  | GWT Analista 2 | 4h |
| 122 | DC-1.4.18 | **Carrito de compras** | 25.5d | 2006-09-12 08:00 | 2006-10-17 12:00 | 83, 112 | 0d |  |  |  | 197.5h |
| 123 | DC-1.4.18.1 | Definición de L&F Carrito | 8h | 2006-09-12 08:00 | 2006-09-12 17:00 |  | 10.5d |  | start no earlier than 2006-09-11 08:00 | DC Diseñador 1 | 8h |
| 124 | DC-1.4.18.2 | Ajuste de L&F Carrito | 40h | 2006-09-27 13:00 | 2006-10-04 12:00 | 123, 121 | 0d |  |  | GWT Lider Proyecto; GWT Analista 2 | 80h |
| 125 | DC-1.4.18.3 | Precio de envío (consideraciones de aliados) | 8h | 2006-10-04 13:00 | 2006-10-05 12:00 | 124 | 4d | 0d |  | GWT Lider Proyecto | 8h |
| 126 | DC-1.4.18.4 | Excentar de IVA a países de Latinoamerica | 8h | 2006-10-05 13:00 | 2006-10-06 12:00 | 125 | 4d | 0d | start no earlier than 2006-09-11 08:00 | GWT Lider Proyecto | 8h |
| 127 | DC-1.4.18.5 | Automatizar precio de Cuentas de Oro | 8h | 2006-10-06 13:00 | 2006-10-09 12:00 | 126 | 4d |  | start no earlier than 2006-09-11 08:00 | GWT Lider Proyecto | 8h |
| 128 | DC-1.4.18.6 | Precio de fotografías de Galería FotoMulà para distintos productos | 16h | 2006-10-13 13:00 | 2006-10-17 12:00 | 127, 133 | 0d |  |  | GWT Lider Proyecto; GWT Analista 2 | 29.5h |
| 129 | DC-1.4.18.7 | **Manejar métodos de pago** | 5d | 2006-10-04 13:00 | 2006-10-11 12:00 |  | 0d |  |  |  | 40h |
| 130 | DC-1.4.18.7.1 | Paypal (requiere investigación) | 24h | 2006-10-04 13:00 | 2006-10-09 12:00 | 124 | 0d |  |  | GWT Analista 2 | 24h |
| 131 | DC-1.4.18.7.2 | Transferencia bancaria | 12h | 2006-10-09 13:00 | 2006-10-10 17:00 | 130 | 0d |  | start no earlier than 2006-09-13 08:00 | GWT Analista 2 | 12h |
| 132 | DC-1.4.18.7.3 | Tarjeta de crédito | 4h | 2006-10-11 08:00 | 2006-10-11 12:00 | 131 | 0d |  | start no earlier than 2006-09-14 08:00 | GWT Analista 2 | 4h |
| 133 | DC-1.4.18.8 | Manejo de precios en dólares y euros | 16h | 2006-10-11 13:00 | 2006-10-13 12:00 | 132 | 0d |  | start no earlier than 2006-08-07 08:00 | GWT Analista 2 | 16h |

| ID | WBS | Task | Duration | Start | Finish | Predecessors | Total slack | Free slack | Constraint | Resources | Work |
| --- | --- | --- | --- | --- | --- | --- | --- | --- | --- | --- | --- |
| 134 | DC-1.4.19 | **Reporte de Compras** | 2d | 2006-10-17 13:00 | 2006-10-19 12:00 | 122 | 4.5d |  |  |  | 16h |
| 135 | DC-1.4.19.1 | Definición de L&F Reporte Compras | 8h | 2006-10-17 13:00 | 2006-10-18 12:00 |  | 4.5d | 0d |  | DC Diseñador 1 | 8h |
| 136 | DC-1.4.19.2 | Ajuste de L&F Reporte Compras | 8h | 2006-10-18 13:00 | 2006-10-19 12:00 | 135 | 4.5d |  |  | GWT Programador 2 | 8h |
| 137 | DC-1.4.20 | **Selecciones** | 21.75d | 2006-09-04 08:00 | 2006-10-03 15:00 | 52 | 8.75d | 0d |  |  | 282h |
| 138 | DC-1.4.20.1 | Definición de L&F Selecciones | 8h | 2006-09-04 08:00 | 2006-09-04 17:00 |  | 9.25d | 0.5d | start no earlier than 2006-09-04 08:00 | DC Diseñador 1 | 8h |
| 139 | DC-1.4.20.2 | Visualización de selecciones | 8h | 2006-09-05 13:00 | 2006-09-06 12:00 | 138, 107 | 8.75d | 0d |  | GWT Analista 1 | 8h |
| 140 | DC-1.4.20.3 | **Creación / edición de una selección** | 6d | 2006-09-06 13:00 | 2006-09-14 12:00 | 139 | 8.75d | 0d |  |  | 96h |
| 141 | DC-1.4.20.3.1 | Escogencia y ordenamiento de fotos | 12h | 2006-09-06 13:00 | 2006-09-07 17:00 |  | 8.75d | 0d |  | GWT Analista 2; GWT Analista 1 | 24h |
| 142 | DC-1.4.20.3.2 | Escogencia de portada y agregar descripción de la selección | 4h | 2006-09-08 08:00 | 2006-09-08 12:00 | 141 | 8.75d | 0d |  | GWT Analista 1; GWT Analista 2 | 8h |
| 143 | DC-1.4.20.3.3 | Permitir la creación de la selección desde la vista de la foto -fotos en conjunto o detalle-, desde la carpeta, desde el home o desde upload. Considerar portada, descripción y ordenamiento. | 24h | 2006-09-08 13:00 | 2006-09-13 12:00 | 142 | 8.75d | 0d |  | GWT Analista 2; GWT Analista 1 | 48h |
| 144 | DC-1.4.20.3.4 | Eliminación de la foto de la selección | 8h | 2006-09-13 13:00 | 2006-09-14 12:00 | 143 | 8.75d |  |  | GWT Analista 2; GWT Analista 1 | 16h |
| 145 | DC-1.4.20.4 | **Visualización del detalle de una foto y edición de imágenes en una selección** | 9.25d | 2006-09-14 13:00 | 2006-09-27 15:00 | 140 | 8.75d | 0d |  |  | 74h |
| 146 | DC-1.4.20.4.1 | Incorporación del carrusel de fotos | 12h | 2006-09-14 13:00 | 2006-09-15 17:00 |  | 8.75d | 0d |  | GWT Analista 1 | 12h |
| 147 | DC-1.4.20.4.2 | Rotar | 16h | 2006-09-18 08:00 | 2006-09-19 17:00 | 146 | 8.75d | 0d |  | GWT Analista 1 | 16h |
| 148 | DC-1.4.20.4.3 | Cambio de permisos: privada, pública, mis amigos, mis grupos | 8h | 2006-09-20 08:00 | 2006-09-20 17:00 | 147 | 8.75d | 0d |  | GWT Analista 1 | 8h |
| 149 | DC-1.4.20.4.4 | Modificación del nombre, tags, Tooltip de la foto | 16h | 2006-09-21 08:00 | 2006-09-22 17:00 | 148 | 8.75d | 0d |  | GWT Analista 1 | 16h |
| 150 | DC-1.4.20.4.5 | Descripción de la foto vinculada a la selección | 8h | 2006-09-25 08:00 | 2006-09-25 17:00 | 149 | 8.75d | 0d |  | GWT Analista 1 | 8h |
| 151 | DC-1.4.20.4.6 | **Comentarios** | 1.75d | 2006-09-26 08:00 | 2006-09-27 15:00 |  | 8.75d |  |  |  | 14h |
| 152 | DC-1.4.20.4.6.1 | Admisión de comentarios | 4h | 2006-09-26 08:00 | 2006-09-26 12:00 | 150 | 8.75d | 0d | start no earlier than 2006-09-25 08:00 | GWT Programador 1 | 4h |
| 153 | DC-1.4.20.4.6.2 | Opción para agregar comentarios | 8h | 2006-09-26 13:00 | 2006-09-27 12:00 | 152 | 8.75d | 0d |  | GWT Programador 1 | 8h |
| 154 | DC-1.4.20.4.6.3 | Despliegue de comentarios | 2h | 2006-09-27 13:00 | 2006-09-27 15:00 | 153 | 8.75d | 0d |  | GWT Programador 1 | 2h |
| 155 | DC-1.4.20.5 | **Visualización de grupo de Fotos** | 4d | 2006-09-27 15:00 | 2006-10-03 15:00 | 145 | 8.75d |  |  |  | 80h |
| 156 | DC-1.4.20.5.1 | Tipo estándar: despliegue por páginas de 20 fotos cada una. | 24h | 2006-09-28 15:00 | 2006-10-03 15:00 | 160 | 8.75d |  | start no earlier than 2006-09-04 08:00 | GWT Analista 1 | 24h |
| 157 | DC-1.4.20.5.2 | Tipo Blog (ver en una sola pantalla todas las fotos con sus comentarios -cuando la foto es comentable-) | 8h | 2006-09-27 15:00 | 2006-09-28 15:00 |  | 11.75d |  | start no earlier than 2006-09-20 08:00 | GWT Programador 2 | 8h |
| 158 | DC-1.4.20.5.3 | Slideshow (investigación paquete existente) | 24h | 2006-09-27 15:00 | 2006-10-02 15:00 |  | 9.75d |  |  | GWT Programador 2; GWT Programador 1 | 48h |

| ID | WBS | Task | Duration | Start | Finish | Predecessors | Total slack | Free slack | Constraint | Resources | Work |
| --- | --- | --- | --- | --- | --- | --- | --- | --- | --- | --- | --- |
| 159 | DC-1.4.20.6 | **Vigencias** | 10.25d | 2006-09-14 13:00 | 2006-09-28 15:00 | 140 | 11.75d |  |  |  | 16h |
| 160 | DC-1.4.20.6.1 | Vigencia de la visualización de una foto en una selección | 8h | 2006-09-27 15:00 | 2006-09-28 15:00 | 154 | 8.75d | 0d |  | GWT Analista 1 | 8h |
| 161 | DC-1.4.20.6.2 | Vigencia de la visualización de la selección | 8h | 2006-09-14 13:00 | 2006-09-15 12:00 |  | 21d |  |  | GWT Analista 2 | 8h |
| 162 | DC-1.4.21 | **FotoBlog** | 12.75d | 2006-10-03 15:00 | 2006-10-20 12:00 | 137 | 2d |  |  |  | 56h |
| 163 | DC-1.4.21.1 | Definición de L&F Fotoblog | 8h | 2006-10-03 15:00 | 2006-10-04 15:00 |  | 10.75d | 0d |  | DC Diseñador 1 | 8h |
| 164 | DC-1.4.21.2 | **Mecanismo de censura de fotos** | 2d | 2006-10-17 13:00 | 2006-10-19 12:00 | 163 | 2d |  |  |  | 16h |
| 165 | DC-1.4.21.2.1 | Facilidad para permitir a un cliente marcar/desmarcar una foto como ofensiva | 8h | 2006-10-17 13:00 | 2006-10-18 12:00 | 128 | 2d | 0d |  | GWT Analista 2 | 8h |
| 166 | DC-1.4.21.2.2 | Reconocimiento de foto como ofensiva para el cliente | 8h | 2006-10-18 13:00 | 2006-10-19 12:00 | 165 | 2d | 0d |  | GWT Analista 2 | 8h |
| 167 | DC-1.4.21.3 | Slideshow (link) | 4h | 2006-10-19 13:00 | 2006-10-19 17:00 | 163, 166 | 2d | 0d |  | GWT Analista 2 [80%] | 3.2h |
| 168 | DC-1.4.21.4 | Acceso a través de URL al estilo www.dichis.com/login_cliente | 16h | 2006-10-04 15:00 | 2006-10-06 15:00 | 163 | 11.25d | 9.25d |  | GWT Analista 1 [80%]; GWT Operaciones 1 [75%] | 24.8h |
| 169 | DC-1.4.21.5 | Pantalla de despliegue de selecciones con fotos blogueables | 4h | 2006-10-20 08:00 | 2006-10-20 12:00 | 168, 167 | 2d | 0d |  | GWT Analista 2 | 4h |
| 170 | DC-1.4.22 | **Compartir: Selecciones** | 15.25d | 2006-10-03 15:00 | 2006-10-24 17:00 | 137 | 1d |  |  |  | 80h |
| 171 | DC-1.4.22.1 | Definición de L&F Selecciones | 8h | 2006-10-03 15:00 | 2006-10-04 15:00 |  | 8.75d |  | start no earlier than 2006-09-04 08:00 | DC Diseñador 1 | 8h |
| 172 | DC-1.4.22.2 | Mecanismo para compartir selecciones a imagen y semejanza de compartir de carpetas en PHS. | 16h | 2006-10-17 13:00 | 2006-10-19 12:00 | 171, 128 | 0d |  | start no earlier than 2006-10-10 08:00 | GWT Lider Proyecto; GWT Analista 1 | 32h |
| 173 | DC-1.4.22.3 | Visualización de selecciones que he compartido. Filtros: compartidas por contactos, públicas, privadas. | 24h | 2006-10-19 13:00 | 2006-10-24 12:00 | 172 | 0d |  |  | GWT Lider Proyecto | 24h |
| 174 | DC-1.4.22.4 | Incluir invitación a contacto no registrado cuando se comparte | 4h | 2006-10-24 13:00 | 2006-10-24 17:00 | 173 | 0d |  |  | GWT Lider Proyecto | 4h |
| 175 | DC-1.4.22.5 | **Notificación de cambios en blogs compartidos** | 1.5d | 2006-10-20 13:00 | 2006-10-23 17:00 | 171, 172 | 2d |  |  |  | 12h |
| 176 | DC-1.4.22.5.1 | Almacenar fecha de modificación de blog. | 4h | 2006-10-20 13:00 | 2006-10-20 17:00 | 169 | 2d | 0d | start no earlier than 2006-09-18 08:00 | GWT Analista 2 | 4h |
| 177 | DC-1.4.22.5.2 | Almacenar fecha de última visita de un contacto al blog. Estudiar mecanismo | 4h | 2006-10-23 08:00 | 2006-10-23 12:00 | 176 | 2d | 0d | start no earlier than 2006-09-18 08:00 | GWT Analista 2 | 4h |
| 178 | DC-1.4.22.5.3 | Indicación de modificación de un blog desde la última visita | 4h | 2006-10-23 13:00 | 2006-10-23 17:00 | 176, 177 | 2d |  | start no earlier than 2006-09-19 08:00 | GWT Analista 1 | 4h |
| 179 | DC-1.4.23 | Compartir: Proyectos Revisar mecanismo actual | 8h | 2006-10-25 08:00 | 2006-10-25 17:00 | 83, 174 | 0d |  |  | GWT Lider Proyecto | 8h |
| 180 | DC-1.4.24 | **Búsqueda de fotos** | 1d | 2006-10-03 15:00 | 2006-10-04 15:00 | 137 | 15.25d |  |  |  | 16h |
| 181 | DC-1.4.24.1 | Búsqueda de fotos por tag en la cabecera de Mi Dichis | 8h | 2006-10-03 15:00 | 2006-10-04 15:00 |  | 15.25d |  |  | GWT Programador 2 | 8h |
| 182 | DC-1.4.24.2 | Búsqueda avanzada utilizando: fecha, usuario, palabras clave, descripción, tamaños, tipo, resolución, precio, metadata. | 8h | 2006-10-03 15:00 | 2006-10-04 15:00 |  | 15.25d |  |  | GWT Programador 2 | 8h |
| 183 | DC-1.4.25 | Ampliación de estadísticas (BO) Productos por categorías por partner | 4h | 2006-10-23 13:00 | 2006-10-23 17:00 | 122, 177 | 2d |  |  | GWT Analista 2 | 4h |

| ID | WBS | Task | Duration | Start | Finish | Predecessors | Total slack | Free slack | Constraint | Resources | Work |
| --- | --- | --- | --- | --- | --- | --- | --- | --- | --- | --- | --- |
| 184 | DC-1.4.26 | **Enlatados** | 2.5d | 2006-07-25 08:00 | 2006-07-27 12:00 | 23 | 65.5d |  |  |  | 28.8h |
| 185 | DC-1.4.26.1 | Revisión de envío de correos automáticos | 8h | 2006-07-25 08:00 | 2006-07-25 17:00 |  | 65.5d | 0d | start no earlier than 2006-07-20 08:00 | GWT Lider Proyecto [10%]; TN Lider Proyecto [50%]; DC Lider Proyecto [90%] | 12h |
| 186 | DC-1.4.26.2 | Definición de correos (enlatados) _idi | 12h | 2006-07-26 08:00 | 2006-07-27 12:00 | 185 | 65.5d |  |  | TN Lider Proyecto [50%]; DC Lider Proyecto [90%] | 16.8h |
| 187 | DC-1.5 | **Implantación** | 13d | 2006-10-26 08:00 | 2006-11-13 17:00 | 17 | 0d |  |  |  | 291.6h |
| 188 | DC-1.5.1 | Entrenamiento al usuario | 8h | 2006-10-26 08:00 | 2006-10-26 17:00 |  | 0d |  |  | TN Lider Proyecto [50%] | 4h |
| 189 | DC-1.5.2 | Definición de templates para puesta al aire | 16h | 2006-10-27 08:00 | 2006-10-30 17:00 | 188 | 0d |  |  | TN Lider Proyecto [50%]; DC Lider Proyecto [90%] | 22.4h |
| 190 | DC-1.5.3 | Migración a ambiente de producción | 8h | 2006-10-26 08:00 | 2006-10-26 17:00 |  | 2d |  | start no earlier than 2006-10-24 08:00 | GWT Lider Proyecto [80%]; GWT Analista 1 [80%]; GWT Analista 2 [80%]; GWT Operaciones 1 [75%] | 25.2h |
| 191 | DC-1.5.4 | Pruebas en ambiente de producción | 40h | 2006-10-31 08:00 | 2006-11-06 17:00 | 189, 190 | 0d |  | start no earlier than 2006-10-22 08:00 | GWT Lider Proyecto; GWT Analista 1; GWT Analista 2 | 120h |
| 192 | DC-1.5.5 | Ajustes tras pruebas en producción | 40h | 2006-11-07 08:00 | 2006-11-13 17:00 | 191 | 0d |  |  | GWT Lider Proyecto; GWT Analista 1; GWT Analista 2 | 120h |
| 193 | DC-1.6 | **Documentación** | 6.25d | 2006-11-14 08:00 | 2006-11-22 10:00 | 187 | 0d |  |  |  | 225h |
| 194 | DC-1.6.1 | Manual de usuario | 50h | 2006-11-14 08:00 | 2006-11-22 10:00 |  | 0d |  |  | TN Lider Proyecto [50%]; DC Lider Proyecto | 75h |
| 195 | DC-1.6.2 | Documentación técnica | 50h | 2006-11-14 08:00 | 2006-11-22 10:00 |  | 0d |  |  | GWT Lider Proyecto; GWT Analista 1; GWT Analista 2 | 150h |
