# Proyecto CRM - Corporacion Union

Schedule from MS Project, 2006-08-07 to 2006-12-08.

## Calendars

- Estándar: Mon-Fri 08:00-12:00, 13:00-17:00; Sat-Sun off.

## Resources

| Resource |
| --- |
| Beta (GWT) |
| Gustavo (GWT) |
| Leonel (GWT) |
| Arne (Tierra) |
| Aron (GWT) |
| Listbeth (GWT) |
| Listbeth (GWT), Beta(GWT) |

## Schedule

| ID | WBS | Task | Type | Duration | Start | Finish | Predecessors | Total slack | Free slack | Constraint |
| --- | --- | --- | --- | --- | --- | --- | --- | --- | --- | --- |
| 1 | 1 | **Total Dealer's Website** |  | 90d? | 2006-08-07 08:00 | 2006-12-08 17:00 |  | 0d |  |  |
| 2 | 1.1 | Kickoff meeting |  | 4h | 2006-10-23 08:00 | 2006-10-23 12:00 |  | 34.5d |  | start no earlier than 2006-10-23 08:00 |
| 3 | 1.2 | **Follow up sessions** |  | 10.25d | 2006-10-30 08:00 | 2006-11-13 10:00 |  | 19.75d |  |  |
| 4 | 1.2.1 | Work session #1 |  | 2h | 2006-10-30 08:00 | 2006-10-30 10:00 |  | 29.75d |  | start no earlier than 2006-10-30 08:00 |
| 5 | 1.2.2 | Work session #2 |  | 2h | 2006-11-06 08:00 | 2006-11-06 10:00 |  | 24.75d |  | start no earlier than 2006-11-06 08:00 |
| 6 | 1.2.3 | Work session #3 |  | 2h | 2006-11-13 08:00 | 2006-11-13 10:00 |  | 19.75d |  | start no earlier than 2006-11-13 08:00 |
| 7 | 1.3 | **Requirements** |  | 12d | 2006-10-24 08:00 | 2006-11-08 17:00 |  | 22d |  |  |
| 8 | 1.3.1 | Analisis and Requirements Elicitation |  | 8h | 2006-10-24 08:00 | 2006-10-24 17:00 |  | 25d | 0d | start no earlier than 2006-10-24 08:00 |
| 9 | 1.3.2 | Requirements Specifications |  | 8h | 2006-10-25 08:00 | 2006-10-25 17:00 | 8 | 25d | 0d | start no earlier than 2006-08-25 08:00 |
| 10 | 1.3.3 | Requirement Specifications Report Elaboration |  | 8h | 2006-10-26 08:00 | 2006-10-26 17:00 | 9 | 25d | 0d |  |
| 11 | 1.3.4 | Document Turn in to the Total Project Team for revision |  | 8h | 2006-10-27 08:00 | 2006-10-27 17:00 | 10 | 25d | 0d | finish no earlier than 2006-10-27 17:00 |
| 12 | 1.3.5 | Total Project Team's document revision |  | 16h | 2006-10-30 08:00 | 2006-10-31 17:00 | 11 | 25d | 0d | finish no earlier than 2006-10-31 17:00 |
| 13 | 1.3.6 | Recommended document adjustemts reception |  | 8h | 2006-11-01 08:00 | 2006-11-01 17:00 | 12 | 25d | 0d | start no earlier than 2006-11-01 08:00 |
| 14 | 1.3.7 | Requirement Specification Report Adjustements |  | 8h | 2006-11-02 08:00 | 2006-11-02 17:00 | 13 | 25d | 0d |  |
| 15 | 1.3.8 | Document Turn in to the Total Project Team for approval |  | 8h | 2006-11-03 08:00 | 2006-11-03 17:00 | 14 | 25d |  | start no earlier than 2006-11-03 08:00 |
| 16 | 1.3.9 | Requirement Specification Report Approval |  | 8h | 2006-11-07 08:00 | 2006-11-07 17:00 |  | 22d | 0d | start no earlier than 2006-11-07 08:00 |
| 17 | 1.3.10 | Requirement Specification Report Approved |  | 8h | 2006-11-08 08:00 | 2006-11-08 17:00 | 16 | 22d |  |  |
| 18 | 1.4 | **Base information preparation for the implementation** |  | 1.5d | 2006-11-07 08:00 | 2006-11-08 12:00 |  | 22.5d |  |  |
| 19 | 1.4.1 | Data Model Definition and Documentation |  | 12h | 2006-11-07 08:00 | 2006-11-08 12:00 |  | 22.5d |  | start no earlier than 2006-11-07 08:00 |
| 20 | 1.4.2 | BackOffice Profiles Definition |  | 1h | 2006-11-08 08:00 | 2006-11-08 09:00 |  | 22.88d |  | start no earlier than 2006-11-08 08:00 |
| 21 | 1.5 | **Design Specifications** |  | 0d? | 2006-11-07 08:00 | 2006-11-07 08:00 |  | 24d |  |  |
| 22 | 1.5.1 | Design Document turn in (colors, typography, images, web pages section sizes) | milestone | 0d? | 2006-11-07 08:00 | 2006-11-07 08:00 |  | 24d |  | start no earlier than 2006-11-07 08:00 |
| 23 | 1.6 | **Configuration and Development** |  | 23d | 2006-11-08 08:00 | 2006-12-08 17:00 |  | 0d |  |  |
| 24 | 1.6.1 | WIB3 Application Configuration |  | 2h | 2006-11-08 08:00 | 2006-11-08 10:00 |  | 22.75d |  | start no earlier than 2006-11-08 08:00 |
| 25 | 1.6.2 | N2C Application Configuration |  | 4h | 2006-11-09 08:00 | 2006-11-09 12:00 |  | 21.5d |  | start no earlier than 2006-11-09 08:00 |

| ID | WBS | Task | Duration | Start | Finish | Predecessors | Total slack | Free slack | Constraint |
| --- | --- | --- | --- | --- | --- | --- | --- | --- | --- |
| 26 | 1.6.3 | **WIB3 Configuration** | 3d | 2006-11-09 08:00 | 2006-11-13 17:00 |  | 19d |  |  |
| 27 | 1.6.3.1 | General Web Site Template Definition (Page Divisions, General Style, Site Assistant) | 16h | 2006-11-09 08:00 | 2006-11-10 17:00 |  | 19d | 0d | start no earlier than 2006-11-09 08:00 |
| 28 | 1.6.3.2 | Page Definition (Content Pages, Application Pages) | 8h | 2006-11-13 08:00 | 2006-11-13 17:00 | 27 | 19d |  |  |
| 29 | 1.6.4 | **Functionalities Implementation** | 19d | 2006-11-14 08:00 | 2006-12-08 17:00 |  | 0d |  |  |
| 30 | 1.6.4.1 | **News** | 1.5d | 2006-11-14 08:00 | 2006-11-15 12:00 |  | 17.5d |  |  |
| 31 | 1.6.4.1.1 | Public Home and User Home News | 8h | 2006-11-14 08:00 | 2006-11-14 17:00 |  | 17.5d | 0d | start no earlier than 2006-11-14 08:00 |
| 32 | 1.6.4.1.2 | Dealerpanel News | 4h | 2006-11-15 08:00 | 2006-11-15 12:00 | 31 | 17.5d |  |  |
| 33 | 1.6.4.2 | Public Home and User Home Poll | 12h | 2006-11-15 08:00 | 2006-11-16 12:00 |  | 16.5d |  | start no earlier than 2006-11-15 08:00 |
| 34 | 1.6.4.3 | **Marketing Actions** | 1.5d | 2006-11-17 08:00 | 2006-11-20 12:00 |  | 14.5d |  |  |
| 35 | 1.6.4.3.1 | Pulbic and User Home Marketing Actions | 8h | 2006-11-17 08:00 | 2006-11-17 17:00 |  | 14.5d | 0d | start no earlier than 2006-11-17 08:00 |
| 36 | 1.6.4.3.2 | Retail-Marketing Actions | 4h | 2006-11-20 08:00 | 2006-11-20 12:00 | 35 | 14.5d |  |  |
| 37 | 1.6.4.4 | Login/Logout/ Password Change | 8h | 2006-11-20 08:00 | 2006-11-20 17:00 |  | 12.5d | 0d | start no earlier than 2006-11-20 08:00 |
| 38 | 1.6.4.5 | User Registration | 12h | 2006-11-21 08:00 | 2006-11-22 12:00 | 37 | 12.5d |  |  |
| 39 | 1.6.4.6 | Price Chart (Like to have) | 8h | 2006-11-22 08:00 | 2006-11-22 17:00 |  | 11d | 0d | start no earlier than 2006-11-22 08:00 |
| 40 | 1.6.4.7 | Links Page (Linkpagina) | 8h | 2006-11-23 08:00 | 2006-11-23 17:00 | 39 | 11d |  |  |
| 41 | 1.6.4.8 | **Mailings** | 2.25d | 2006-11-24 08:00 | 2006-11-28 10:00 |  | 8.75d |  |  |
| 42 | 1.6.4.8.1 | User home Mailing | 8h | 2006-11-24 08:00 | 2006-11-24 17:00 |  | 9.75d | 0d | start no earlier than 2006-11-24 08:00 |
| 43 | 1.6.4.8.2 | Retail-Marketing Mailing | 2h | 2006-11-27 08:00 | 2006-11-27 10:00 | 42 | 9.75d |  |  |
| 44 | 1.6.4.8.3 | Retail-Top Service & Training Mailing | 2h | 2006-11-27 08:00 | 2006-11-27 10:00 | 42 | 9.75d |  |  |
| 45 | 1.6.4.8.4 | Retail-Shop Food & Services Mailing | 2h | 2006-11-27 08:00 | 2006-11-27 10:00 | 42 | 9.75d |  |  |
| 46 | 1.6.4.8.5 | Retail-Enginoring Mailing | 2h | 2006-11-27 08:00 | 2006-11-27 10:00 | 42 | 9.75d |  |  |
| 47 | 1.6.4.8.6 | Retail-Customer Service Mailing | 2h | 2006-11-28 08:00 | 2006-11-28 10:00 |  | 8.75d |  | start no earlier than 2006-11-28 08:00 |
| 48 | 1.6.4.8.7 | Retail-Power Points Mailing | 2h | 2006-11-28 08:00 | 2006-11-28 10:00 |  | 8.75d |  | start no earlier than 2006-11-28 08:00 |
| 49 | 1.6.4.8.8 | Cards Mailings | 2h | 2006-11-28 08:00 | 2006-11-28 10:00 |  | 8.75d |  | start no earlier than 2006-11-28 08:00 |
| 50 | 1.6.4.8.9 | Lubricants Mailings | 2h | 2006-11-28 08:00 | 2006-11-28 10:00 |  | 8.75d |  | start no earlier than 2006-11-28 08:00 |
| 51 | 1.6.4.9 | Pesonal Agenda | 8h | 2006-11-29 08:00 | 2006-11-29 17:00 |  | 7d |  | start no earlier than 2006-11-29 08:00 |
| 52 | 1.6.4.10 | Meeting Agenda | 16h | 2006-11-30 08:00 | 2006-12-01 17:00 |  | 5d |  | start no earlier than 2006-11-30 08:00 |

| ID | WBS | Task | Type | Duration | Start | Finish | Total slack | Constraint |
| --- | --- | --- | --- | --- | --- | --- | --- | --- |
| 53 | 1.6.4.11 | **Contact Forms** |  | 3.25d | 2006-12-04 08:00 | 2006-12-07 10:00 | 1.75d |  |
| 54 | 1.6.4.11.1 | Retail-Sales Contact |  | 12h | 2006-12-04 08:00 | 2006-12-05 12:00 | 3.5d | start no earlier than 2006-12-04 08:00 |
| 55 | 1.6.4.11.2 | Retail-Marketing Contact |  | 2h | 2006-12-05 08:00 | 2006-12-05 10:00 | 3.75d | start no earlier than 2006-12-05 08:00 |
| 56 | 1.6.4.11.3 | Retail-Top Service & Training Contact |  | 2h | 2006-12-05 08:00 | 2006-12-05 10:00 | 3.75d | start no earlier than 2006-12-05 08:00 |
| 57 | 1.6.4.11.4 | Retail-Shop Food & Services Contact |  | 2h | 2006-12-06 08:00 | 2006-12-06 10:00 | 2.75d | start no earlier than 2006-12-06 08:00 |
| 58 | 1.6.4.11.5 | Retail-Customer Service Contact |  | 2h | 2006-12-06 08:00 | 2006-12-06 10:00 | 2.75d | start no earlier than 2006-12-06 08:00 |
| 59 | 1.6.4.11.6 | Retail-Power Points Contact |  | 2h | 2006-12-06 08:00 | 2006-12-06 10:00 | 2.75d | start no earlier than 2006-12-06 08:00 |
| 60 | 1.6.4.11.7 | Cards Contact |  | 2h | 2006-12-06 08:00 | 2006-12-06 10:00 | 2.75d | start no earlier than 2006-12-06 08:00 |
| 61 | 1.6.4.11.8 | Dealerpanel Contact |  | 2h | 2006-12-07 08:00 | 2006-12-07 10:00 | 1.75d | start no earlier than 2006-12-07 08:00 |
| 62 | 1.6.4.12 | Acts Module |  | 16h | 2006-12-07 08:00 | 2006-12-08 17:00 | 0d | start no earlier than 2006-12-07 08:00 |
| 63 | 1.7 | **Testing Plan** |  | 1d | 2006-08-07 08:00 | 2006-08-07 17:00 | 89d |  |
| 64 | 1.7.1 | Testing Plan Elaboration |  | 8h | 2006-08-07 08:00 | 2006-08-07 17:00 | 89d |  |
| 65 | 1.7.2 | Testing Plan revision with Total Work Team |  | 4h | 2006-08-07 08:00 | 2006-08-07 12:00 | 89.5d |  |
| 66 | 1.7.3 | Recommended Adjustments to the Testing Plan |  | 4h | 2006-08-07 08:00 | 2006-08-07 12:00 | 89.5d |  |
| 67 | 1.8 | Revised Testing Plan |  | 4h | 2006-08-07 08:00 | 2006-08-07 12:00 | 89.5d |  |
| 68 | 1.9 | **Certification Testing** |  | 2d | 2006-08-07 08:00 | 2006-08-08 17:00 | 88d |  |
| 69 | 1.9.1 | Testing Preparation |  | 4h | 2006-08-07 08:00 | 2006-08-07 12:00 | 89.5d |  |
| 70 | 1.9.2 | Functionalities Testing |  | 8h | 2006-08-07 08:00 | 2006-08-07 17:00 | 89d |  |
| 71 | 1.9.3 | Recommended Adjustments |  | 16h | 2006-08-07 08:00 | 2006-08-08 17:00 | 88d |  |
| 72 | 1.10 | Certified Testing |  | 8h | 2006-08-07 08:00 | 2006-08-07 17:00 | 89d |  |
| 73 | 1.11 | **Documentation** |  | 2d | 2006-08-07 08:00 | 2006-08-08 17:00 | 88d |  |
| 74 | 1.11.1 | Technical documentation consolidation and structuring |  | 16h | 2006-08-07 08:00 | 2006-08-08 17:00 | 88d |  |
| 75 | 1.11.2 | Documentation Adjustements |  | 4h | 2006-08-07 08:00 | 2006-08-07 12:00 | 89.5d |  |
| 76 | 1.12 | Change Management | milestone | 0d? | 2006-08-07 08:00 | 2006-08-07 08:00 | 90d |  |

| ID | WBS | Task | Type | Duration | Start | Finish | Total slack |
| --- | --- | --- | --- | --- | --- | --- | --- |
| 77 | 1.13 | **Project Management** |  | 0d? | 2006-08-07 08:00 | 2006-08-07 08:00 | 90d |
| 78 | 1.13.1 | Planification | milestone | 0d? | 2006-08-07 08:00 | 2006-08-07 08:00 | 90d |
| 79 | 1.13.2 | Follow up and management | milestone | 0d? | 2006-08-07 08:00 | 2006-08-07 08:00 | 90d |
| 80 | 1.14 | **Project Closure** |  | 0.5d | 2006-08-07 08:00 | 2006-08-07 12:00 | 89.5d |
| 81 | 1.14.1 | Project Closure Presentation Elaboration |  | 4h | 2006-08-07 08:00 | 2006-08-07 12:00 | 89.5d |
| 82 | 1.14.2 | Project Closure Meeting |  | 4h | 2006-08-07 08:00 | 2006-08-07 12:00 | 89.5d |
