# Proyecto CRM - Corporacion Union

Schedule from MS Project, 2006-09-11 to 2007-01-15.

## Calendars

- Estándar: Mon-Fri 08:00-12:00, 13:00-17:00; Sat-Sun off. Exceptions (off unless hours are given): 2006-12-25, 2007-01-01.

## Resources

| Resource |
| --- |
| LR |
| BC-Merc |
| GS |
| BC-Sist |
| Aron |
| FA |
| AG |
| RC |
| Lore |
| BC-CG |
| AB |
| EUCV |
| Pprofit |

## Schedule

| ID | WBS | Task | Type | Duration | Start | Finish | Predecessors | Total slack | Free slack | Constraint | Resources | Work |
| --- | --- | --- | --- | --- | --- | --- | --- | --- | --- | --- | --- | --- |
| 1 | 1 | **Proyecto Egresados UCV** |  | 89d | 2006-09-11 | 2007-01-15 |  | 0d |  |  |  | 961.65h |
| 2 | 1.1 | Reunión de Arranque |  | 0.11d | 2006-11-14 | 2006-11-14 |  | 31.89d |  | start no earlier than 2006-11-14 |  | 3h |
| 3 | 1.2 | Análsis y preparación material para definición requerimientos |  | 1d | 2006-11-20 | 2006-11-20 |  | 37d |  | start no earlier than 2006-11-20 | LR | 8h |
| 4 | 1.3 | **Especificación de Requerimientos** |  | 11d | 2006-11-23 | 2006-12-07 |  | 25d |  |  |  | 36h |
| 5 | 1.3.1 | **Levantamiento de Información** |  | 4.17d | 2006-11-23 | 2006-11-29 |  | 31.83d |  |  |  | 8h |
| 6 | 1.3.1.1 | Mesa de Trabajo #1 |  | 0.25d | 2006-11-23 | 2006-11-23 |  | 34.75d |  | start no earlier than 2006-11-23 | LR; EUCV | 4h |
| 7 | 1.3.1.2 | Mesa de Trabajo #2 |  | 0.17d | 2006-11-29 | 2006-11-29 |  | 30.83d |  | start no earlier than 2006-11-29 | LR; AB; EUCV | 4h |
| 8 | 1.3.2 | Elaboración del Informe Especificación de Req. |  | 3d | 2006-11-29 | 2006-12-01 |  | 28d |  | start no earlier than 2006-11-29 | LR [50%] | 12h |
| 9 | 1.3.3 | Entrega al Equipo de Proyecto E.UCV para su revisión | milestone | 0d | 2006-12-01 | 2006-12-01 |  | 15d | 0d | start no earlier than 2006-12-01 |  |  |
| 10 | 1.3.4 | Revisión por parte del Equipo de Proyecto E. UCV |  | 2d | 2006-12-01 | 2006-12-04 | 9 | 15d | 0d |  | EUCV [50%] | 8h |
| 11 | 1.3.5 | Recepción de ajustes recomendados al Informe | milestone | 0d | 2006-12-04 | 2006-12-04 | 10 | 15d | 0d |  |  |  |
| 12 | 1.3.6 | Ajustes al Informe Especificación de Requerimientos |  | 1d | 2006-12-05 | 2006-12-05 | 11 | 15d | 1d |  | LR [50%] | 4h |
| 13 | 1.3.7 | Entrega de Especificación de Req. para aprobación | milestone | 0d | 2006-12-07 | 2006-12-07 | 12 | 14d | 0d | start no earlier than 2006-12-07 | LR |  |
| 14 | 1.3.8 | Aprobación del Informe Especificación de Requerimientos |  | 1d | 2006-12-07 | 2006-12-07 | 13 | 14d | 0d | start no earlier than 2006-09-15 | EUCV [50%] | 4h |
| 15 | 1.3.9 | Informe Especificación de Requerimientos Aprobado | milestone | 0d | 2006-12-07 | 2006-12-07 | 14 | 14d | 0d |  |  |  |
| 16 | 1.4 | **Preparación de la información base para implantación** |  | 4d | 2006-09-11 | 2006-09-15 |  | 85d |  |  |  | 16h |
| 17 | 1.4.1 | Usuarios y perfiles |  | 2d | 2006-09-11 | 2006-09-12 |  | 86d |  | start no earlier than 2006-09-11 | EUCV | 16h |
| 18 | 1.4.2 | Entrega de información para implantación a GWT | milestone | 0d | 2006-09-15 | 2006-09-15 |  | 79d |  | start no earlier than 2006-09-15 |  |  |
| 19 | 1.5 | **Configuración y Desarrollo** |  | 27d | 2006-11-16 | 2006-12-22 |  | 14d |  |  |  | 308.65h |
| 20 | 1.5.1 | Creación estructura WiB3 para la Página Web |  | 2d | 2006-11-16 | 2006-11-17 |  | 35d |  | start no earlier than 2006-11-16 | Aron [12.5%] | 2h |
| 21 | 1.5.2 | Creación de aplicaciones en N2C |  | 2d | 2006-11-21 | 2006-11-22 |  | 32d |  | start no earlier than 2006-11-21 | Aron [12.5%] | 2h |
| 22 | 1.5.3 | **Configuración WiB3** |  | 13d | 2006-11-22 | 2006-12-08 |  | 24d |  |  |  | 42h |
| 23 | 1.5.3.1 | Diseño Preliminar |  | 5d | 2006-11-22 | 2006-11-28 |  | 19d | 0d | start no earlier than 2006-11-22 | FA [50%] | 20h |
| 24 | 1.5.3.2 | Preparación y presentación prototipo |  | 2d | 2006-11-29 | 2006-11-30 | 23 | 19d | 0d |  | FA [50%] | 8h |
| 25 | 1.5.3.3 | Presentación y aprobación a la Asociación de E. UCV |  | 1d | 2006-12-01 | 2006-12-01 | 24 | 19d | 0d |  | EUCV [25%] | 2h |
| 26 | 1.5.3.4 | Ajustes sobre recomendaciones Asociacion E. UCV |  | 5d | 2006-12-04 | 2006-12-08 | 25 | 20d |  |  | FA [30%] | 12h |

Notes:
- 21: esto es la creación de las Aplicaciones por parte de Aron

| ID | WBS | Task | Type | Duration | Start | Finish | Predecessors | Total slack | Free slack | Constraint | Resources | Work |
| --- | --- | --- | --- | --- | --- | --- | --- | --- | --- | --- | --- | --- |
| 27 | 1.5.4 | **Configuración Nuevas Aplicaciones** |  | 25d | 2006-11-20 | 2006-12-22 |  | 13d |  |  |  | 222.65h |
| 28 | 1.5.4.1 | Directorio de Egresados y Amigos de la UCV |  | 9d | 2006-11-20 | 2006-11-30 |  | 14d | 0d | start no earlier than 2006-11-20 | AB [55.6%] | 40h |
| 29 | 1.5.4.2 | Contáctanos |  | 4d | 2006-12-01 | 2006-12-06 | 28 | 12d | 0d |  | AB [50%] | 16h |
| 30 | 1.5.4.3 | Emisión de Carnets |  | 4d | 2006-12-07 | 2006-12-12 | 29 | 12d | 0d | start no earlier than 2006-01-31 | AB [50%] | 16h |
| 31 | 1.5.4.4 | Administración de Banners |  | 3d | 2006-12-13 | 2006-12-15 | 30 | 12d | 0d | start no earlier than 2006-08-21 | AB [66.7%] | 16h |
| 32 | 1.5.4.5 | Galería de Imágenes |  | 2d | 2006-12-18 | 2006-12-19 | 31 | 12d | 0d | start no earlier than 2006-02-13 | AB | 16h |
| 33 | 1.5.4.6 | Blog |  | 2d | 2006-12-20 | 2006-12-21 | 32 | 12d | 0d | start no earlier than 2006-02-10 | AB | 16h |
| 34 | 1.5.4.7 | Integración Profit Plus |  | 18d | 2006-11-29 | 2006-12-22 |  | 13d |  | start no earlier than 2006-11-29 | AB [33.3%]; Pprofit [40%]; LR [20%] | 102.65h |
| 35 | 1.5.5 | **Configuración WiB3** |  | 11d | 2006-12-04 | 2006-12-18 |  | 18d |  |  |  | 40h |
| 36 | 1.5.5.1 | Definición páginas (Tipo Contenido, Aplicación) |  | 4d | 2006-12-04 | 2006-12-07 | 25 | 19d | 5d | start no earlier than 2006-09-18 | FA [50%]; LR [50%] | 24h |
| 37 | 1.5.5.2 | Definición de aplicaciones N2C |  | 2d | 2006-12-15 | 2006-12-18 | 36 | 14d |  | start no earlier than 2006-12-15 | LR | 16h |
| 38 | 1.6 | Funcionalidades de la Página Web incorporadas | milestone | 0d | 2006-12-19 | 2006-12-19 |  | 1d | 0d | start no earlier than 2006-12-19 |  |  |
| 39 | 1.7 | **Plan de Pruebas** |  | 7d | 2006-12-19 | 2006-12-28 |  | 11d |  |  |  | 52h |
| 40 | 1.7.1 | Elaboración Plan de Pruebas |  | 4d | 2006-12-19 | 2006-12-22 | 15 | 10d | 0d | start no earlier than 2006-12-19 | LR | 32h |
| 41 | 1.7.2 | Revisión Plan de Pruebas con Equipo de Trabajo |  | 2d | 2006-12-26 | 2006-12-27 | 40 | 10d | 0d |  | LR [50%]; EUCV [50%] | 16h |
| 42 | 1.7.3 | Ajustes recomendados al Plan de Pruebas |  | 1d | 2006-12-28 | 2006-12-28 | 41 | 10d | 0d |  | LR [50%] | 4h |
| 43 | 1.8 | Plan de Pruebas elaborado y revisado | milestone | 0d | 2006-12-28 | 2006-12-28 | 42 | 10d |  |  |  |  |
| 44 | 1.9 | **Pruebas de Certificación** |  | 9d | 2006-12-22 | 2007-01-05 |  | 2d |  |  |  | 66h |
| 45 | 1.9.1 | Preparación para las pruebas en ambiente de desarrollo |  | 1d | 2006-12-22 | 2006-12-22 | 38 | 2d | 0d | start no earlier than 2006-12-22 | LR [25%] | 2h |
| 46 | 1.9.2 | Realización de Pruebas de Funcionalidad |  | 5d | 2006-12-26 | 2007-01-02 | 45 | 2d | 0d | start no earlier than 2005-07-12 | LR [50%]; EUCV [50%] | 40h |
| 47 | 1.9.3 | Realización de Ajustes recomendados |  | 3d | 2007-01-03 | 2007-01-05 | 46 | 2d | 0d |  | AB [60%]; FA [30%]; LR [10%] | 24h |
| 48 | 1.10 | Pruebas Certificadas | milestone | 0d | 2007-01-05 | 2007-01-05 | 47 | 2d | 0d |  |  |  |
| 49 | 1.11 | **Documentación** |  | 11d | 2006-12-22 | 2007-01-09 |  | 4d |  |  |  | 36h |
| 50 | 1.11.1 | Consolidación y estructuración de documentos técnicos |  | 2d | 2006-12-22 | 2006-12-26 | 33 | 12d |  |  | LR [25%] | 4h |
| 51 | 1.11.2 | Ajustes a la documentación |  | 2d | 2007-01-08 | 2007-01-09 | 48 | 3d |  |  | LR [25%]; AB [50%] | 12h |
| 52 | 1.11.3 | Técnica WIB |  | 5d | 2007-01-03 | 2007-01-09 |  | 3d |  | start no earlier than 2007-01-03 | FA [50%] | 20h |

Notes:
- 28: Se tomó en cuenta los días de ausencia de Andrey por Graduación

| ID | WBS | Task | Type | Duration | Start | Finish | Predecessors | Total slack | Free slack | Constraint | Resources | Work |
| --- | --- | --- | --- | --- | --- | --- | --- | --- | --- | --- | --- | --- |
| 53 | 1.12 | **Migración de versiones N2C y WiB en Banco Caroní** |  | 4d | 2007-01-04 | 2007-01-09 |  | 4d |  |  |  | 32h |
| 54 | 1.12.1 | **Ambiente de Producción** |  | 4d | 2007-01-04 | 2007-01-09 |  | 4d |  |  |  | 32h |
| 55 | 1.12.1.1 | Planificación y Configuración Infraestructura Técnica |  | 2d | 2007-01-04 | 2007-01-05 |  | 3d | 0d | start no earlier than 2007-01-04 | Aron | 16h |
| 56 | 1.12.1.2 | Pruebas y ajustes aplicaciones existentes |  | 2d | 2007-01-08 | 2007-01-09 | 55 | 3d | 0d |  | LR [60%]; AB [40%] | 16h |
| 57 | 1.12.2 | Ambiente de Producción con nuevas versiones | milestone | 0d | 2007-01-09 | 2007-01-09 | 56 | 3d |  |  |  |  |
| 58 | 1.13 | **Adiestramiento** |  | 3d | 2007-01-10 | 2007-01-12 |  | 1d |  |  |  | 48h |
| 59 | 1.13.1 | WiB3 |  | 1d | 2007-01-10 | 2007-01-10 |  | 1d | 0d | start no earlier than 2007-01-10 | FA; LR | 16h |
| 60 | 1.13.2 | Aplicaciones |  | 2d | 2007-01-11 | 2007-01-12 | 59 | 1d |  |  | LR; AB | 32h |
| 61 | 1.14 | **Puesta en Producción** |  | 3d | 2007-01-08 | 2007-01-10 |  | 2d |  |  |  | 24h |
| 62 | 1.14.1 | Migración de aplicaciones |  | 2d | 2007-01-08 | 2007-01-09 | 48 | 2d | 0d |  | Aron [50%] | 8h |
| 63 | 1.14.2 | Pruebas integrales |  | 1d | 2007-01-10 | 2007-01-10 | 62 | 2d |  |  | LR; EUCV | 16h |
| 64 | 1.15 | **Gerencia de Proyecto** |  | 42d | 2006-11-14 | 2007-01-12 |  | 1d |  |  |  | 300h |
| 65 | 1.15.1 | Planificación |  | 18d | 2006-11-14 | 2006-12-07 |  | 24d |  | start no earlier than 2006-11-14 | LR [13.9%] | 20h |
| 66 | 1.15.2 | Control y Seguimiento |  | 35d | 2006-11-23 | 2007-01-12 |  | 1d |  | finish no earlier than 2007-01-12 | LR | 280h |
| 67 | 1.16 | **Cierre** |  | 3d | 2007-01-11 | 2007-01-15 |  | 0d |  |  |  | 32h |
| 68 | 1.16.1 | Preparación Presentación Cierre de Proyecto |  | 2d | 2007-01-11 | 2007-01-12 |  | 1d |  | start no earlier than 2007-01-11 | LR | 16h |
| 69 | 1.16.2 | Reunión Cierre de Proyecto |  | 1d | 2007-01-15 | 2007-01-15 | 61 | 0d |  | start no earlier than 2007-01-15 | LR; EUCV | 16h |

Notes:
- 60: Incluye aplicaciones nuevas: / Directorio de Relacionados, Administración de Banners, Emisión de Carnets, Galería de Imágenes, Contáctanos, Blog
