# Vendinet

Schedule from MS Project, 2006-12-18 to 2007-02-19, costs in Bs.
GlobalWebTek

## Calendars

- Standard: Mon-Fri 08:00-12:00, 13:00-17:00; Sat-Sun off. Exceptions (off unless hours are given): 2006-12-25, 2007-01-01.

## Resources

| Resource | Rate |
| --- | --- |
| MR | 15000 |
| FB | 6250 |
| AL | 15000 |
| FA |  |

## Schedule

| ID | WBS | Task | Duration | Start | Finish | Predecessors | Total slack | Free slack | Constraint | Resources | Work | Cost |
| --- | --- | --- | --- | --- | --- | --- | --- | --- | --- | --- | --- | --- |
| 1 | 1 | **Control de Servicios de Infraestructura** | 44d? | 2006-12-18 | 2007-02-19 |  | 0d |  |  |  | 370h | 3,035,000 |
| 2 | 1.1 | **Inicio** | 0.5d | 2006-12-18 | 2006-12-18 |  | 0.5d |  |  |  | 4h | 60,000 |
| 3 | 1.1.1 | Reunión de Kickoff | 4h | 2006-12-18 | 2006-12-18 |  | 0.5d | 0d | start no earlier than 2006-12-18 | MR | 4h | 60,000 |
| 4 | 1.2 | **FASE I** | 43.5d? | 2006-12-18 | 2007-02-19 |  | 0d |  |  |  | 353h | 2,780,000 |
| 5 | 1.2.1 | Análisis y Diseño | 1.5d | 2006-12-18 | 2006-12-19 | 3 | 0.5d | 0d |  | MR; FB | 24h | 255,000 |
| 6 | 1.2.2 | **Construcción** | 38.75d? | 2006-12-20 | 2007-02-14 |  | 0.5d | 0d |  |  | 284h | 1,850,000 |
| 7 | 1.2.2.1 | **Construcción Funcionalidades** | 38.75d? | 2006-12-20 | 2007-02-14 |  | 0.5d |  |  |  | 268h | 1,850,000 |
| 8 | 1.2.2.1.1 | Registros de datos | 2.5d? | 2006-12-20 | 2006-12-22 | 5 | 0.5d | 0d |  | FB [80%] | 16h | 100,000 |
| 9 | 1.2.2.1.2 | Módulo Mis Ventas | 3.12d | 2006-12-22 | 2006-12-28 | 8 | 0.5d | 0d |  | FB [80%] | 20h | 125,000 |
| 10 | 1.2.2.1.3 | Módulo Recepción de Pagos | 2.5d | 2006-12-28 | 2007-01-03 | 9 | 0.5d | 0d |  | FB [80%] | 16h | 100,000 |
| 11 | 1.2.2.1.4 | Módulo Mis Clientes | 2.5d | 2007-01-03 | 2007-01-05 | 10 | 0.5d | 0d |  | FB [80%] | 16h | 100,000 |
| 12 | 1.2.2.1.5 | Módulo Mis Artículos | 1.25d | 2007-01-05 | 2007-01-08 | 11 | 0.5d | 0d |  | FB [80%] | 8h | 50,000 |
| 13 | 1.2.2.1.6 | Módulo Mis Envíos | 2.5d? | 2007-01-08 | 2007-01-11 | 12 | 0.5d | 0d |  | FB [80%] | 16h | 100,000 |
| 14 | 1.2.2.1.7 | Módulo Mis Configuraciones | 3.75d? | 2007-01-11 | 2007-01-17 | 13 | 0.5d | 0d |  | FB [80%] | 24h | 150,000 |
| 15 | 1.2.2.1.8 | Módulo Administración | 11.25d? | 2007-01-17 | 2007-02-01 | 14 | 0.5d | 0d |  | FB [80%] | 72h | 450,000 |
| 16 | 1.2.2.1.9 | Notificaciones Tareas Pendientes | 1.25d? | 2007-02-01 | 2007-02-02 | 15 | 0.5d | 0d |  | FB [80%] | 8h | 50,000 |
| 17 | 1.2.2.1.10 | Blog Vendinet | 3.75d? | 2007-02-02 | 2007-02-08 | 16, 15 | 0.5d | 0d |  | FB [80%] | 24h | 150,000 |
| 18 | 1.2.2.1.11 | Home | 1.25d? | 2007-02-08 | 2007-02-09 | 17 | 0.5d | 0d |  | FB [80%] | 8h | 50,000 |
| 19 | 1.2.2.1.12 | Pruebas Internas y Ajustes | 1.25d | 2007-02-09 | 2007-02-12 | 18 | 0.5d | 0d |  | MR; FB [80%] | 16h | 170,000 |
| 20 | 1.2.2.1.13 | Guías de Usuario | 1.88d | 2007-02-12 | 2007-02-14 | 19 | 0.5d |  |  | MR; FB [80%] | 24h | 255,000 |
| 21 | 1.2.2.2 | **Diseño Gráfico** | 2d? | 2006-12-20 | 2006-12-21 |  | 37.25d |  |  |  | 16h |  |
| 22 | 1.2.2.2.1 | CSS | 1d? | 2006-12-20 | 2006-12-20 | 5 | 34.25d | 0d |  | FA | 8h |  |
| 23 | 1.2.2.2.2 | Aplicación de CSS al Site | 1d? | 2006-12-21 | 2006-12-21 | 22 | 34.25d |  |  | FA | 8h |  |
| 24 | 1.2.3 | Pruebas de Certificación | 1.5d | 2007-02-14 | 2007-02-16 | 6 | 0.5d | 0d |  | MR | 12h | 180,000 |

| ID | WBS | Task | Type | Duration | Start | Finish | Predecessors | Total slack | Free slack | Constraint | Resources | Work | Cost |
| --- | --- | --- | --- | --- | --- | --- | --- | --- | --- | --- | --- | --- | --- |
| 25 | 1.2.4 | **Puesta en Marcha** |  | 1.25d | 2007-02-16 | 2007-02-19 |  | 0.5d | 0d |  |  | 10h | 150,000 |
| 26 | 1.2.4.1 | Adiestramiento Administración |  | 2h | 2007-02-16 | 2007-02-16 | 24 | 0.5d | 0d |  | MR | 2h | 30,000 |
| 27 | 1.2.4.2 | Implantación Fase I |  | 1d | 2007-02-16 | 2007-02-19 | 26 | 0.5d |  |  | AL | 8h | 120,000 |
| 28 | 1.2.5 | Reuniones de Seguimiento Fase I |  | 328.57h | 2006-12-20 | 2007-02-19 | 5 | 0d |  | finish no earlier than 2007-02-19 | MR [7%] | 23h | 345,000 |
| 29 | 1.2.6 | Módulos Fase I | milestone | 0d | 2007-02-19 | 2007-02-19 | 25 | 0.5d |  |  |  |  |  |
| 30 | 1.3 | **Gerencia de Proyecto** |  | 40.62d | 2006-12-21 | 2007-02-19 |  | 0d |  |  |  | 13h | 195,000 |
| 31 | 1.3.1 | Planificación, Control, Seguimiento |  | 40.62d | 2006-12-21 | 2007-02-19 | 5 | 0d |  | finish no earlier than 2007-02-19 | MR [4%] | 13h | 195,000 |
