# Proyecto CRM - Corporacion Union

Schedule from MS Project, 2007-09-10 to 2008-01-17.

## Calendars

- Estándar: Mon-Fri 08:00-12:00, 13:00-17:00; Sat-Sun off. Exceptions (off unless hours are given): 2007-10-12, 2007-12-24.

## Resources

| Resource |
| --- |
| R1 |
| Gerente |
| Usuario |
| Rvelasquez |
| Operaciones |
| Consultor |
| R2 |

## Schedule

| ID | WBS | Task | Type | Duration | Start | Finish | Predecessors | Total slack | Free slack | Constraint | Resources | Work |
| --- | --- | --- | --- | --- | --- | --- | --- | --- | --- | --- | --- | --- |
| 1 | 1 | **Conversión Monetaria Génesis** |  | 92d | 2007-09-10 | 2008-01-17 |  | 0d |  |  |  | 331.3h |
| 2 | 1.1 | **Inicio** |  | 0.38d | 2007-09-10 | 2007-09-10 |  | 0d |  |  |  | 3h |
| 3 | 1.1.1 | Reunión de Arranque (Kickoff) |  | 0.38d | 2007-09-10 | 2007-09-10 |  | 0d |  | start no earlier than 2007-09-10 | Gerente | 3h |
| 4 | 1.2 | **Especificación de Requerimientos** |  | 3d | 2007-09-11 | 2007-09-13 |  | 77.56d | 0d |  |  | 12h |
| 5 | 1.2.1 | Elaboración del Informe Esp. de Req. |  | 1d | 2007-09-11 | 2007-09-11 |  | 77.56d | 0d | start no earlier than 2007-09-11 | Gerente | 8h |
| 6 | 1.2.2 | Revisión por parte del Equipo de Proyecto |  | 0.5d | 2007-09-12 | 2007-09-12 | 5 | 77.56d | 0d |  | Gerente [50%] | 2h |
| 7 | 1.2.3 | Ajustes al Informe Especificación de Requerimientos |  | 0.5d | 2007-09-12 | 2007-09-12 | 6 | 77.56d | 0d |  | Gerente [50%] | 2h |
| 8 | 1.2.4 | Revisión por parte del Cliente |  | 1d | 2007-09-13 | 2007-09-13 | 7 | 77.56d | 0d |  |  |  |
| 9 | 1.2.5 | Aprobación del Informe Especificación de Requerimientos | milestone | 0d | 2007-09-13 | 2007-09-13 | 8 | 77.56d | 0d |  |  |  |
| 10 | 1.3 | Informe Especificación de Requerimientos Aprobado | milestone | 0d | 2007-09-13 | 2007-09-13 | 9 | 88d |  |  |  |  |
| 11 | 1.4 | **Configuración y Desarrollo** |  | 66.34d | 2007-09-14 | 2007-12-18 |  | 21.66d |  |  |  | 134.5h |
| 12 | 1.4.1 | **Fase 1 - 1ro Octubre** |  | 10.44d | 2007-09-14 | 2007-09-28 |  | 77.56d |  |  |  | 31.5h |
| 13 | 1.4.1.1 | Impreso Total Cotiz, Reserv en pantalla e email |  | 3.88d | 2007-09-14 | 2007-09-19 | 4 | 84.12d |  |  | R1 [25%] | 7.75h |
| 14 | 1.4.1.2 | Impresión Total en BsF Reporte Siniestro |  | 0.88d | 2007-09-14 | 2007-09-14 | 4 | 77.56d | 0d |  | R1 [25%] | 1.75h |
| 15 | 1.4.1.3 | Pruebas Internas y Ajustes |  | 3.64d | 2007-09-14 | 2007-09-20 | 14 | 77.56d | 0d |  | R1 [25%]; R2 [25%] | 8h |
| 16 | 1.4.1.4 | **Pruebas de Certificación** |  | 5.2d | 2007-09-20 | 2007-09-27 |  | 77.56d | 0d |  |  | 8h |
| 17 | 1.4.1.4.1 | Pruebas del Cliente |  | 1d | 2007-09-20 | 2007-09-21 | 15 | 77.56d | 0d |  |  |  |
| 18 | 1.4.1.4.2 | Ajustes |  | 3.2d | 2007-09-21 | 2007-09-26 | 17 | 77.56d | 0d |  | R1 [25%]; R2 [25%] | 8h |
| 19 | 1.4.1.4.3 | Certificación por parte del Cliente |  | 1d | 2007-09-26 | 2007-09-27 | 18 | 77.56d |  |  |  |  |
| 20 | 1.4.1.5 | Pase a producción |  | 0.73d | 2007-09-27 | 2007-09-28 | 16 | 77.56d | 0d |  | R1 [50%]; Operaciones | 6h |
| 21 | 1.4.1.6 | Sistema con Conversión Monetaria Req. 01/10 | milestone | 0d | 2007-09-28 | 2007-09-28 | 20 | 77.56d |  |  |  |  |
| 22 | 1.4.2 | **Fase 2 - Enero 2007** |  | 50.34d | 2007-10-08 | 2007-12-18 |  | 21.11d |  |  |  | 103h |
| 23 | 1.4.2.1 | Modificación de Impresión-Devolver cambios |  | 8d | 2007-10-08 | 2007-10-18 |  | 21.11d | 0d | start no earlier than 2007-10-08 | R1 [25%]; R2 [25%] | 20h |
| 24 | 1.4.2.2 | Pruebas Internas y Ajustes |  | 3.2d | 2007-10-19 | 2007-10-24 | 23 | 21.11d | 0d |  | R1 [25%]; R2 [25%] | 8h |
| 25 | 1.4.2.3 | Preparación de scripts para cambiar valores a BsF |  | 20d | 2007-10-24 | 2007-11-21 | 24 | 21.11d | 0d |  | R1 [25%] | 40h |
| 26 | 1.4.2.4 | Scripts para limpieza de datos que quedarán en Producción |  | 2.5d | 2007-11-21 | 2007-11-23 | 25 | 21.11d | 0d |  | R2 [25%] | 5h |
| 27 | 1.4.2.5 | Prueba y ajustes de los scripts |  | 4.44d | 2007-11-23 | 2007-11-30 | 26 | 21.11d | 0d |  | R1 [25%]; Gerente [10%]; R2 [25%] | 12h |

| ID | WBS | Task | Type | Duration | Start | Finish | Predecessors | Total slack | Free slack | Constraint | Resources | Work |
| --- | --- | --- | --- | --- | --- | --- | --- | --- | --- | --- | --- | --- |
| 28 | 1.4.2.6 | **Pruebas de Certificación** |  | 9d | 2007-11-30 | 2007-12-13 |  | 21.11d | 0d |  |  | 10h |
| 29 | 1.4.2.6.1 | Pruebas del Cliente |  | 5d | 2007-11-30 | 2007-12-07 | 27 | 21.11d | 0d |  |  |  |
| 30 | 1.4.2.6.2 | Ajustes |  | 4d | 2007-12-07 | 2007-12-13 | 29 | 21.11d |  |  | R1 [25%]; R2 [25%] | 10h |
| 31 | 1.4.2.7 | **Documentación** |  | 3.2d | 2007-12-13 | 2007-12-18 |  | 21.66d |  |  |  | 8h |
| 32 | 1.4.2.7.1 | Instructivo para Implantación en Producción |  | 3.2d | 2007-12-13 | 2007-12-18 | 28 | 21.66d |  |  | R1 [25%]; R2 [25%] | 8h |
| 33 | 1.5 | **Replicación Génesis** |  | 33.89d | 2007-11-01 | 2007-12-18 |  | 21.11d |  |  |  | 36h |
| 34 | 1.5.1 | Definición de perfiles |  | 2d | 2007-11-01 | 2007-11-02 |  | 44.4d | 0d | start no earlier than 2007-11-01 |  |  |
| 35 | 1.5.2 | Replicación de Génesis a ambiente prod |  | 3.75d | 2007-12-13 | 2007-12-18 | 28 | 21.11d |  |  | Rvelasquez; R1 [20%]; Operaciones [50%] | 12h |
| 36 | 1.5.3 | Ajuste Usuarios y Perfiles |  | 1.6d | 2007-11-05 | 2007-11-06 | 34 | 44.4d | 0d |  | Gerente [25%]; R2 | 16h |
| 37 | 1.5.4 | Prueba de Perfiles |  | 3d | 2007-11-06 | 2007-11-09 | 36 | 44.4d | 0d |  |  |  |
| 38 | 1.5.5 | Ajustes perfiles |  | 1d | 2007-11-09 | 2007-11-12 | 37 | 44.4d | 0d |  | R2 | 8h |
| 39 | 1.5.6 | Certificación Réplica |  | 2d | 2007-11-12 | 2007-11-14 | 38 | 44.4d | 0d |  |  |  |
| 40 | 1.5.7 | Réplica Sistema en producción |  | 1d | 2007-11-14 | 2007-11-15 | 39 | 44.4d |  |  |  |  |
| 41 | 1.6 | **Puesta Producción 31/12** |  | 1d | 2007-12-31 | 2007-12-31 |  | 9.72d | 0d |  |  | 16h |
| 42 | 1.6.1 | Actualización BD en réplica | milestone | 0d | 2007-12-31 | 2007-12-31 |  | 10.72d | 0d | start no earlier than 2007-12-31 | Rvelasquez |  |
| 43 | 1.6.2 | Implantación Impresiones en Producción | milestone | 0d | 2007-12-31 | 2007-12-31 | 42 | 10.72d | 0d |  | Rvelasquez |  |
| 44 | 1.6.3 | Ejecución scripts | milestone | 0d | 2007-12-31 | 2007-12-31 | 43 | 10.72d | 0d |  | Rvelasquez |  |
| 45 | 1.6.4 | Revisión de muestra para comprobar correctitud | milestone | 0d | 2007-12-31 | 2007-12-31 | 44 | 10.72d |  |  | Rvelasquez |  |
| 46 | 1.6.5 | Guardia de Recurso de GWT |  | 1d | 2007-12-31 | 2007-12-31 |  | 9.72d | 0d | start no earlier than 2007-12-31 | R2 [200%] | 16h |
| 47 | 1.6.6 | Sistema en Producción | milestone | 0d | 2007-12-31 | 2007-12-31 | 46 | 9.72d |  |  |  |  |
| 48 | 1.7 | Soporte Post implantación |  | 3.28d | 2008-01-01 | 2008-01-04 | 41 | 9.72d |  |  | R1; Gerente [10%]; Consultor [30%] | 14h |
| 49 | 1.8 | Consultoría |  | 3.75d | 2007-09-14 | 2007-09-19 | 4 | 84.25d |  |  | Consultor | 30h |
| 50 | 1.9 | **Cierre** |  | 0.38d | 2008-01-02 | 2008-01-02 |  | 11.62d |  |  |  | 3h |
| 51 | 1.9.1 | Preparación presentación de Cierre y Acta de Cierre |  | 0.12d | 2008-01-02 | 2008-01-02 |  | 11.62d | 0d | start no earlier than 2008-01-02 | Gerente | 1h |
| 52 | 1.9.2 | Reunión Cierre de Proyecto |  | 0.25d | 2008-01-02 | 2008-01-02 | 51 | 11.62d |  |  | Gerente | 2h |

| ID | WBS | Task | Duration | Start | Finish | Predecessors | Total slack | Resources | Work |
| --- | --- | --- | --- | --- | --- | --- | --- | --- | --- |
| 53 | 1.10 | **Gerencia de Proyecto** | 91.62d | 2007-09-10 | 2008-01-17 |  | 0d |  | 82.8h |
| 54 | 1.10.1 | Planificación | 2.22d | 2007-09-14 | 2007-09-18 | 4 | 85.78d | Gerente [45%] | 8h |
| 55 | 1.10.2 | Control y Seguimiento | 91.62d | 2007-09-10 | 2008-01-17 | 3 | 0d | Gerente [10.2%] | 74.8h |
